# PROGRAMACION MERCADO

Schedule from MS Project, 2026-05-01 to 2027-04-25, costs in S.

## Calendars

- Estándar: Mon-Sat 09:00-13:00, 15:00-19:00; Sun off. Exceptions (off unless hours are given): 2027-04-25 09:00-13:00, 15:00-19:00.

## Schedule

| ID | WBS | Task | Type | Duration | Start | Finish | Predecessors | Total slack | Free slack | Cost | Text2 | Text1 |
| --- | --- | --- | --- | --- | --- | --- | --- | --- | --- | --- | --- | --- |
| 1 | 1 | **"CREACION DEL SERVICIO DE ACCESIBILIDAD A LA ADQUISICIÓN DE PRODUCTOS DE PRIMERA NECESIDAD EN EL MERCADO DE ABASTOS DEL CENTRO POB** |  | 309d | 2026-05-01 | 2027-04-25 |  | 0d |  | 6,912,240.07 | 360 días |  |
| 2 | 1.1 | Inicio de Obra | milestone | 0d | 2026-05-01 | 2026-05-01 |  | 0d |  |  | 0 días |  |
| 3 | 1.2 | **OBRAS PROVISIONALES, TRABAJOS PRELIMINARES, SEGURIDAD Y SALUD.** |  | 307d | 2026-05-01 | 2027-04-23 |  | 2d |  | 765,220.7 | 358 días |  |
| 4 | 1.2.1 | **OBRAS PROVISIONALES, TRABAJOS PRELIMINARES, SEGURIDAD Y SALUD** |  | 307d | 2026-05-01 | 2027-04-23 |  | 2d |  | 765,220.7 | 358 días | 01 |
| 5 | 1.2.1.1 | **OBRAS PROVISIONALES Y TRABAJOS PRELIMINARES** |  | 307d | 2026-05-01 | 2027-04-23 |  | 2d |  | 728,464.37 | 358 días | 01.01 |
| 6 | 1.2.1.1.1 | **OBRAS PROVISIONALES** |  | 7d | 2026-05-01 | 2026-05-08 |  | 287d |  | 16,363.62 | 8 días | 01.01.01 |
| 7 | 1.2.1.1.1.1 | ALMACEN, OFICINAS Y CASETA DE GUARDIANIA |  | 1d | 2026-05-01 | 2026-05-01 | 8SS | 307d |  | 5,145 | 1 día | 01.01.01.01 |
| 8 | 1.2.1.1.1.2 | CERCO DE OBRA CON POSTES DE MADERA Y MALLA ARPILLERA |  | 7d | 2026-05-01 | 2026-05-08 | 2 | 286d | 0d | 8,976 | 8 días | 01.01.01.02 |
| 9 | 1.2.1.1.1.3 | CARTEL DE OBRA (3.60 X 2.40M - C/BANNER) |  | 1d | 2026-05-01 | 2026-05-01 | 8SS | 306d | 0d | 742.52 | 1 día | 01.01.01.03 |
| 10 | 1.2.1.1.1.4 | GUARDIANIA PARA LA OBRA |  | 1d | 2026-05-01 | 2026-05-01 | 8SS | 307d |  | 1,500.1 | 1 día | 01.01.01.04 |
| 11 | 1.2.1.1.2 | **INSTALACIONES PROVISIONALES** |  | 1d | 2026-05-02 | 2026-05-02 |  | 307d |  | 22,500 | 1 día | 01.01.02 |
| 12 | 1.2.1.1.2.1 | AGUA PARA LA CONSTRUCCIÓN |  | 1d | 2026-05-02 | 2026-05-02 | 9 | 306d |  | 7,500 | 1 día | 01.01.02.01 |
| 13 | 1.2.1.1.2.2 | DESAGÜE PARA LA CONSTRUCCIÓN |  | 1d | 2026-05-02 | 2026-05-02 | 9 | 306d |  | 7,500 | 1 día | 01.01.02.02 |
| 14 | 1.2.1.1.2.3 | ENERGÍA ELÉCTRICA PROVISIONAL |  | 1d | 2026-05-02 | 2026-05-02 | 9 | 306d |  | 7,500 | 1 día | 01.01.02.03 |
| 15 | 1.2.1.1.3 | **TRABAJOS PRELIMINARES** |  | 15d | 2026-05-09 | 2026-05-26 |  | 287d |  | 5,096 | 18 días | 01.01.03 |
| 16 | 1.2.1.1.3.1 | LIMPIEZA DEL TERRENO MANUAL |  | 15d | 2026-05-09 | 2026-05-26 | 8 | 286d |  | 5,096 | 18 días | 01.01.03.01 |
| 17 | 1.2.1.1.4 | **MOVILIZACIÓN DE CAMPAMENTO, MAQUINARIA Y HERRAMIENTAS** |  | 307d | 2026-05-01 | 2027-04-23 |  | 2d |  | 3,000 | 358 días | 01.01.04 |
| 18 | 1.2.1.1.4.1 | MOVILIZACION Y DESMOVILIZACION DE EQUIPOS Y HERRAMIENTAS |  | 8d | 2026-05-01 | 2027-04-23 |  | 1d |  | 3,000 | 358 días | 01.01.04.01 |
| 19 | 1.2.1.1.5 | **TRAZOS, NIVELES Y REPLANTEO** |  | 7d | 2026-05-09 | 2026-05-16 |  | 295d |  | 9,996 | 8 días | 01.01.05 |
| 20 | 1.2.1.1.5.1 | TRAZO, NIVELES Y REPLANTEO PRELIMINAR |  | 7d | 2026-05-09 | 2026-05-16 | 8 | 294d | 0d | 7,784 | 8 días | 01.01.05.01 |
| 21 | 1.2.1.1.5.2 | TRAZO Y REPLANTEO DURANTE EL PROCESO DE EJECUCIÓN |  | 7d | 2026-05-09 | 2026-05-16 | 20SS | 294d |  | 2,212 | 8 días | 01.01.05.02 |
| 22 | 1.2.1.1.6 | **MOVIMIENTO DE TIERRAS** |  | 231d | 2026-05-01 | 2027-01-25 |  | 78d |  | 671,508.75 | 270 días | 01.01.06 |
| 23 | 1.2.1.1.6.1 | CORTE DE TERRENO C/EQUIPO |  | 231d | 2026-05-01 | 2027-01-25 | 2 | 78d | 0d | 85,898 | 270 días | 01.01.06.01 |
| 24 | 1.2.1.1.6.2 | ACARREO DE MATERIAL EXCEDENTE PROVENIENTE DE EXCAVACION MANUAL |  | 231d | 2026-05-01 | 2027-01-25 | 23SS | 78d | 0d | 288,718.86 | 270 días | 01.01.06.02 |
| 25 | 1.2.1.1.6.3 | ELIMINACION DE MATERIAL EXCEDENTE C/EQUIPO |  | 231d | 2026-05-01 | 2027-01-25 | 24FF | 78d |  | 296,891.89 | 270 días | 01.01.06.03 |

| ID | WBS | Task | Duration | Start | Finish | Predecessors | Total slack | Free slack | Cost | Text1 | Text2 |
| --- | --- | --- | --- | --- | --- | --- | --- | --- | --- | --- | --- |
| 26 | 1.2.1.2 | **SEGURIDAD Y SALUD** | 300d | 2026-05-01 | 2027-04-15 |  | 9d |  | 36,756.33 | 01.02 | 350 días |
| 27 | 1.2.1.2.1 | ELABORACION DE PLAN DE SEGURIDAD | 1d | 2026-05-01 | 2026-05-01 | 2 | 8d | 0d | 3,500 | 01.02.01 | 1 día |
| 28 | 1.2.1.2.2 | EQUIPOS DE PROTECCIÓN INDIVIDUAL | 1d | 2026-05-01 | 2026-05-01 | 27SS | 307d |  | 15,413 | 01.02.02 | 1 día |
| 29 | 1.2.1.2.3 | EQUIPOS DE PROTECCIÓN COLECTIVA | 1d | 2026-05-01 | 2026-05-01 | 27SS | 307d |  | 3,500 | 01.02.03 | 1 día |
| 30 | 1.2.1.2.4 | SEÑALIZACIÓN TEMPORAL DE SEGURIDAD | 1d | 2026-05-01 | 2026-05-01 | 27SS | 307d |  | 843.33 | 01.02.04 | 1 día |
| 31 | 1.2.1.2.5 | CAPACITACION EN SEGURIDAD Y SALUD | 1d | 2026-05-01 | 2026-05-01 | 27SS | 307d |  | 3,000 | 01.02.05 | 1 día |
| 32 | 1.2.1.2.6 | BAÑOS QUIMICOS PORTATILES PARA EL PERSONAL DE OBRA | 300d | 2026-05-01 | 2027-04-15 | 27SS | 8d |  | 10,500 | 01.02.06 | 350 días |
| 33 | 1.3 | **BLOQUE N°1** | 237d | 2026-05-01 | 2027-02-01 |  | 0d |  | 1,911,356.92 |  | 277 días |
| 34 | 1.3.1 | **ESTRUCTURAS** | 141d | 2026-05-01 | 2026-10-12 |  | 0d |  | 843,111.86 | 02 | 165 días |
| 35 | 1.3.1.1 | **MOVIMIENTO DE TIERRAS** | 16d | 2026-05-01 | 2026-05-19 |  | 0d |  | 25,187.26 | 02.01 | 19 días |
| 36 | 1.3.1.1.1 | EXCAVACION MANUAL DE ZANJAS Y ZAPATAS | 16d | 2026-05-01 | 2026-05-19 | 2 | 0d |  | 8,583.87 | 02.01.01 | 19 días |
| 37 | 1.3.1.1.2 | CORTE DE TERRENO C/EQUIPO | 2d | 2026-05-01 | 2026-05-02 | 36SS | 221d | 0d | 3,330.62 | 02.01.02 | 2 días |
| 38 | 1.3.1.1.3 | RELLENO COMPACTADO CON MATERIAL PROPIO 7.0HP | 2d | 2026-05-04 | 2026-05-05 | 37 | 221d | 0d | 2,197.81 | 02.01.03 | 2 días |
| 39 | 1.3.1.1.4 | ELIMINACION DE MATERIAL EXCEDENTE C/EQUIPO | 2d | 2026-05-06 | 2026-05-07 | 38 | 302d |  | 11,074.96 | 02.01.04 | 2 días |
| 40 | 1.3.1.2 | **OBRAS DE CONCRETO SIMPLE** | 23d | 2026-05-07 | 2026-06-02 |  | 0d |  | 29,255.97 | 02.02 | 27 días |
| 41 | 1.3.1.2.1 | CONCRETO PARA CIMIENTOS CICLOPEO 1:10 + 30% P.G. | 2d | 2026-06-01 | 2026-06-02 | 48 | 280d |  | 12,144.81 | 02.02.01 | 2 días |
| 42 | 1.3.1.2.2 | CONCRETO PARA SOLADOS E=0.10m C:H, 1:12 | 2d | 2026-05-07 | 2026-05-09 | 50SF | 301d |  | 3,078.18 | 02.02.02 | 3 días |
| 43 | 1.3.1.2.3 | CONCRETO PARA SOBRECIMIENTOS CICLOPEO 1:8 + 25% P.M. | 1d | 2026-06-01 | 2026-06-01 | 48 | 281d |  | 3,585.46 | 02.02.03 | 1 día |
| 44 | 1.3.1.2.4 | CONCRETO PARA FALSO PISO E=4" MEZCLA 1:8 C:H | 2d | 2026-05-07 | 2026-05-08 | 36SS+5d | 0d |  | 10,447.52 | 02.02.04 | 2 días |
| 45 | 1.3.1.3 | **OBRAS DE CONCRETO ARMADO** | 134d | 2026-05-09 | 2026-10-12 |  | 0d |  | 788,668.63 | 02.03 | 157 días |
| 46 | 1.3.1.3.1 | **PRIMER NIVEL** | 93d | 2026-05-09 | 2026-08-25 |  | 0d |  | 370,578 | 02.03.01 | 109 días |
| 47 | 1.3.1.3.1.1 | **ZAPATAS** | 19d | 2026-05-09 | 2026-05-30 |  | 0d |  | 63,645.86 | 02.03.01.01 | 22 días |
| 48 | 1.3.1.3.1.1.1 | CONCRETO f'c=210Kg/cm2 PARA ZAPATAS | 5d | 2026-05-26 | 2026-05-30 | 49 | 0d |  | 22,212.96 | 02.03.01.01.01 | 5 días |
| 49 | 1.3.1.3.1.1.2 | ENCOFRADO Y DESENCOFRADO NORMAL PARA ZAPATAS | 11d | 2026-05-13 | 2026-05-25 | 50SS+3d | 0d |  | 5,927.9 | 02.03.01.01.02 | 13 días |
| 50 | 1.3.1.3.1.1.3 | ACERO GRADO 60, EN ZAPATAS | 14d | 2026-05-09 | 2026-05-25 | 44 | 0d |  | 35,505 | 02.03.01.01.03 | 17 días |

| ID | WBS | Task | Duration | Start | Finish | Predecessors | Total slack | Free slack | Cost | Text1 | Text2 |
| --- | --- | --- | --- | --- | --- | --- | --- | --- | --- | --- | --- |
| 51 | 1.3.1.3.1.2 | **COLUMNAS** | 31d | 2026-05-26 | 2026-06-30 |  | 0d |  | 82,834.68 | 02.03.01.02 | 36 días |
| 52 | 1.3.1.3.1.2.1 | CONCRETO f'c=210Kg/cm2 PARA COLUMNAS | 19d | 2026-06-09 | 2026-06-30 | 53SS+7d | 0d |  | 23,332.46 | 02.03.01.02.01 | 22 días |
| 53 | 1.3.1.3.1.2.2 | ENCOFRADO Y DESENCOFRADO NORMAL PARA COLUMNAS | 21d | 2026-06-01 | 2026-06-24 | 54SS+5d | 0d |  | 26,427.22 | 02.03.01.02.02 | 24 días |
| 54 | 1.3.1.3.1.2.3 | ACERO GRADO 60, EN COLUMNAS | 20d | 2026-05-26 | 2026-06-17 | 48SS | 0d |  | 33,075 | 02.03.01.02.03 | 23 días |
| 55 | 1.3.1.3.1.3 | **VIGAS** | 48d | 2026-07-01 | 2026-08-25 |  | 0d |  | 43,115.41 | 02.03.01.03 | 56 días |
| 56 | 1.3.1.3.1.3.1 | CONCRETO f'c=210Kg/cm2 PARA VIGAS | 15d | 2026-08-08 | 2026-08-25 | 58FS+14d | 208d |  | 13,984.08 | 02.03.01.03.01 | 18 días |
| 57 | 1.3.1.3.1.3.2 | ENCOFRADO Y DESENCOFRADO NORMAL PARA VIGAS | 14d | 2026-07-01 | 2026-07-16 | 52 | 0d |  | 17,414.21 | 02.03.01.03.02 | 16 días |
| 58 | 1.3.1.3.1.3.3 | ACERO GRADO 60, EN VIGAS | 12d | 2026-07-09 | 2026-07-22 | 57SS+7d | 208d | 0d | 11,717.12 | 02.03.01.03.03 | 14 días |
| 59 | 1.3.1.3.1.4 | **LOSAS** | 23d | 2026-07-01 | 2026-07-27 |  | 0d |  | 111,619.58 | 02.03.01.04 | 27 días |
| 60 | 1.3.1.3.1.4.1 | **LOSAS ALIGERADAS** | 23d | 2026-07-01 | 2026-07-27 |  | 0d |  | 111,619.58 | 02.03.01.04.01 | 27 días |
| 61 | 1.3.1.3.1.4.1.1 | CONCRETO f'c=210Kg/cm2 PARA LOSAS ALIGERADAS | 3d | 2026-07-13 | 2026-07-15 | 64 | 155d | 0d | 11,620.14 | 02.03.01.04.01.01 | 3 días |
| 62 | 1.3.1.3.1.4.1.2 | ENCOFRADO Y DESENCOFRADO NORMAL PARA LOSAS ALIGERADAS | 20d | 2026-07-01 | 2026-07-27 | 57SS | 0d |  | 18,256.64 | 02.03.01.04.01.02 | 27 días |
| 63 | 1.3.1.3.1.4.1.3 | LADRILLO PARA LOSA ALIGERADA 0.20x0.30x0.30m | 2d | 2026-07-04 | 2026-07-06 | 62SS+3d | 163d |  | 10,138.8 | 02.03.01.04.01.03 | 3 días |
| 64 | 1.3.1.3.1.4.1.4 | ACERO GRADO 60, EN LOSAS ALIGERADAS | 7d | 2026-07-04 | 2026-07-11 | 62SS+3d | 155d | 0d | 71,604 | 02.03.01.04.01.04 | 8 días |
| 65 | 1.3.1.3.1.5 | **ESCALERAS** | 15d | 2026-07-16 | 2026-08-01 |  | 229d |  | 47,603.77 | 02.03.01.05 | 17 días |
| 66 | 1.3.1.3.1.5.1 | CONCRETO f'c=210Kg/cm2 PARA ESCALERAS | 6d | 2026-07-27 | 2026-08-01 | 68 | 228d |  | 34,516.71 | 02.03.01.05.01 | 6 días |
| 67 | 1.3.1.3.1.5.2 | ENCOFRADO Y DESENCOFRADO NORMAL PARA ESCALERAS | 4d | 2026-07-16 | 2026-07-20 | 61 | 228d | 0d | 1,929.31 | 02.03.01.05.02 | 5 días |
| 68 | 1.3.1.3.1.5.3 | ACERO GRADO 60, EN ESCALERAS | 7d | 2026-07-18 | 2026-07-25 | 67FS-2d | 228d | 0d | 11,157.75 | 02.03.01.05.03 | 8 días |
| 69 | 1.3.1.3.1.6 | **CAJA DE ASCENSORES Y SIMILARES** | 31d | 2026-05-26 | 2026-06-30 |  | 257d |  | 21,758.7 | 02.03.01.06 | 36 días |
| 70 | 1.3.1.3.1.6.1 | CONCRETO f'c=210Kg/cm2 PARA ASCENSORES | 15d | 2026-06-13 | 2026-06-30 | 71 | 256d |  | 3,403.18 | 02.03.01.06.01 | 18 días |
| 71 | 1.3.1.3.1.6.2 | ENCOFRADO Y DESENCOFRADO NORMAL PARA ASCENSORES | 7d | 2026-06-05 | 2026-06-12 | 72 | 256d | 0d | 5,329.66 | 02.03.01.06.02 | 8 días |
| 72 | 1.3.1.3.1.6.3 | ACERO GRADO 60, EN ASCENSORES | 9d | 2026-05-26 | 2026-06-04 | 54SS | 256d | 0d | 13,025.86 | 02.03.01.06.03 | 10 días |
| 73 | 1.3.1.3.2 | **SEGUNDO NIVEL** | 41d | 2026-07-20 | 2026-09-04 |  | 0d |  | 171,745.05 | 02.03.02 | 47 días |
| 74 | 1.3.1.3.2.1 | **COLUMNAS** | 19d | 2026-07-20 | 2026-08-10 |  | 0d |  | 82,863.46 | 02.03.02.01 | 22 días |
| 75 | 1.3.1.3.2.1.1 | CONCRETO f'c=210Kg/cm2 PARA COLUMNAS | 6d | 2026-07-28 | 2026-08-03 | 76SS+4d | 227d |  | 21,129.38 | 02.03.02.01.01 | 7 días |
| 76 | 1.3.1.3.2.1.2 | ENCOFRADO Y DESENCOFRADO NORMAL PARA COLUMNAS | 10d | 2026-07-23 | 2026-08-10 | 77SS+3d | 0d |  | 23,934.08 | 02.03.02.01.02 | 19 días |
| 77 | 1.3.1.3.2.1.3 | ACERO GRADO 60, EN COLUMNAS | 7d | 2026-07-20 | 2026-07-27 | 62FS-7d | 0d |  | 37,800 | 02.03.02.01.03 | 8 días |

| ID | WBS | Task | Duration | Start | Finish | Predecessors | Total slack | Free slack | Cost | Text1 | Text2 |
| --- | --- | --- | --- | --- | --- | --- | --- | --- | --- | --- | --- |
| 78 | 1.3.1.3.2.2 | **VIGAS** | 22d | 2026-08-11 | 2026-09-04 |  | 200d |  | 44,789.28 | 02.03.02.02 | 25 días |
| 79 | 1.3.1.3.2.2.1 | CONCRETO f'c=210Kg/cm2 PARA VIGAS | 7d | 2026-08-21 | 2026-08-28 | 81 | 205d |  | 13,984.08 | 02.03.02.02.01 | 8 días |
| 80 | 1.3.1.3.2.2.2 | ENCOFRADO Y DESENCOFRADO NORMAL PARA VIGAS | 15d | 2026-08-11 | 2026-09-04 | 76 | 199d | 0d | 17,414.21 | 02.03.02.02.02 | 25 días |
| 81 | 1.3.1.3.2.2.3 | ACERO GRADO 60, EN VIGAS | 7d | 2026-08-13 | 2026-08-20 | 80SS+2d | 205d | 0d | 13,390.99 | 02.03.02.02.03 | 8 días |
| 82 | 1.3.1.3.2.3 | **LOSAS** | 20d | 2026-08-11 | 2026-09-02 |  | 0d |  | 21,800.52 | 02.03.02.03 | 23 días |
| 83 | 1.3.1.3.2.3.1 | **LOSAS ALIGERADAS** | 20d | 2026-08-11 | 2026-09-02 |  | 0d |  | 21,800.52 | 02.03.02.03.01 | 23 días |
| 84 | 1.3.1.3.2.3.1.1 | CONCRETO f'c=210Kg/cm2 PARA LOSAS ALIGERADAS | 6d | 2026-08-20 | 2026-08-26 | 87 | 207d |  | 2,269.02 | 02.03.02.03.01.01 | 7 días |
| 85 | 1.3.1.3.2.3.1.2 | ENCOFRADO Y DESENCOFRADO NORMAL PARA LOSAS ALIGERADAS | 14d | 2026-08-11 | 2026-09-02 | 76 | 0d |  | 3,566.09 | 02.03.02.03.01.02 | 23 días |
| 86 | 1.3.1.3.2.3.1.3 | LADRILLO PARA LOSA ALIGERADA 0.20x0.30x0.30m | 4d | 2026-08-13 | 2026-08-17 | 87SS | 215d |  | 1,980.22 | 02.03.02.03.01.03 | 5 días |
| 87 | 1.3.1.3.2.3.1.4 | ACERO GRADO 60, EN LOSAS ALIGERADAS | 6d | 2026-08-13 | 2026-08-19 | 85SS+2d | 207d | 0d | 13,985.19 | 02.03.02.03.01.04 | 7 días |
| 88 | 1.3.1.3.2.4 | **CAJA DE ASCENSORES Y SIMILARES** | 16d | 2026-07-20 | 2026-08-06 |  | 225d |  | 22,291.79 | 02.03.02.04 | 18 días |
| 89 | 1.3.1.3.2.4.1 | CONCRETO f'c=210Kg/cm2 PARA ASCENSORES | 3d | 2026-07-28 | 2026-07-30 | 91 | 230d |  | 3,082.02 | 02.03.02.04.01 | 3 días |
| 90 | 1.3.1.3.2.4.2 | ENCOFRADO Y DESENCOFRADO NORMAL PARA ASCENSORES | 10d | 2026-07-23 | 2026-08-06 | 91SS+3d | 224d |  | 4,826.86 | 02.03.02.04.02 | 15 días |
| 91 | 1.3.1.3.2.4.3 | ACERO GRADO 60, EN ASCENSORES | 7d | 2026-07-20 | 2026-07-27 | 62FS-7d | 224d | 0d | 14,382.91 | 02.03.02.04.03 | 8 días |
| 92 | 1.3.1.3.3 | **TERCER NIVEL** | 76d | 2026-07-16 | 2026-10-12 |  | 42d |  | 246,345.58 | 02.03.03 | 89 días |
| 93 | 1.3.1.3.3.1 | **COLUMNAS** | 23d | 2026-09-03 | 2026-09-29 |  | 0d |  | 58,421.08 | 02.03.03.01 | 27 días |
| 94 | 1.3.1.3.3.1.1 | CONCRETO f'c=210Kg/cm2 PARA COLUMNAS | 7d | 2026-09-15 | 2026-09-22 | 96 | 0d |  | 11,883.16 | 02.03.03.01.01 | 8 días |
| 95 | 1.3.1.3.3.1.2 | ENCOFRADO Y DESENCOFRADO NORMAL PARA COLUMNAS | 16d | 2026-09-03 | 2026-09-29 | 96SS | 178d |  | 13,462.92 | 02.03.03.01.02 | 27 días |
| 96 | 1.3.1.3.3.1.3 | ACERO GRADO 60, EN COLUMNAS | 10d | 2026-09-03 | 2026-09-14 | 85 | 0d |  | 33,075 | 02.03.03.01.03 | 12 días |
| 97 | 1.3.1.3.3.2 | **VIGAS** | 17d | 2026-09-23 | 2026-10-12 |  | 168d |  | 42,186.84 | 02.03.03.02 | 20 días |
| 98 | 1.3.1.3.3.2.1 | CONCRETO f'c=210Kg/cm2 PARA VIGAS | 2d | 2026-10-03 | 2026-10-05 | 100 | 173d |  | 13,984.08 | 02.03.03.02.01 | 3 días |
| 99 | 1.3.1.3.3.2.2 | ENCOFRADO Y DESENCOFRADO NORMAL PARA VIGAS | 15d | 2026-09-23 | 2026-10-12 | 94 | 167d | 0d | 16,485.64 | 02.03.03.02.02 | 20 días |
| 100 | 1.3.1.3.3.2.3 | ACERO GRADO 60, EN VIGAS | 6d | 2026-09-26 | 2026-10-02 | 99SS+3d | 173d | 0d | 11,717.12 | 02.03.03.02.03 | 7 días |
| 101 | 1.3.1.3.3.3 | **LOSAS** | 17d | 2026-09-23 | 2026-10-12 |  | 0d |  | 111,619.58 | 02.03.03.03 | 20 días |
| 102 | 1.3.1.3.3.3.1 | **LOSAS ALIGERADAS** | 17d | 2026-09-23 | 2026-10-12 |  | 0d |  | 111,619.58 | 02.03.03.03.01 | 20 días |
| 103 | 1.3.1.3.3.3.1.1 | CONCRETO f'c=210Kg/cm2 PARA LOSAS ALIGERADAS | 2d | 2026-10-03 | 2026-10-05 | 106 | 173d |  | 11,620.14 | 02.03.03.03.01.01 | 3 días |
| 104 | 1.3.1.3.3.3.1.2 | ENCOFRADO Y DESENCOFRADO NORMAL PARA LOSAS ALIGERADAS | 15d | 2026-09-23 | 2026-10-12 | 94 | 0d |  | 18,256.64 | 02.03.03.03.01.02 | 20 días |
| 105 | 1.3.1.3.3.3.1.3 | LADRILLO PARA LOSA ALIGERADA 0.20x0.30x0.30m | 2d | 2026-09-26 | 2026-09-28 | 106SS | 179d |  | 10,138.8 | 02.03.03.03.01.03 | 3 días |
| 106 | 1.3.1.3.3.3.1.4 | ACERO GRADO 60, EN LOSAS ALIGERADAS | 6d | 2026-09-26 | 2026-10-02 | 104SS+3d | 0d |  | 71,604 | 02.03.03.03.01.04 | 7 días |

| ID | WBS | Task | Duration | Start | Finish | Predecessors | Total slack | Free slack | Cost | Text1 | Text2 |
| --- | --- | --- | --- | --- | --- | --- | --- | --- | --- | --- | --- |
| 107 | 1.3.1.3.3.4 | **CAJA DE ASCENSORES Y SIMILARES** | 37d | 2026-07-16 | 2026-08-27 |  | 207d |  | 34,118.08 | 02.03.03.04 | 43 días |
| 108 | 1.3.1.3.3.4.1 | CONCRETO f'c=210Kg/cm2 PARA ASCENSORES | 15d | 2026-08-11 | 2026-08-27 | 109 | 206d |  | 8,220.59 | 02.03.03.04.01 | 17 días |
| 109 | 1.3.1.3.3.4.2 | ENCOFRADO Y DESENCOFRADO NORMAL PARA ASCENSORES | 13d | 2026-07-27 | 2026-08-10 | 110 | 206d | 0d | 12,871.63 | 02.03.03.04.02 | 15 días |
| 110 | 1.3.1.3.3.4.3 | ACERO GRADO 60, EN ASCENSORES | 9d | 2026-07-16 | 2026-07-25 | 61 | 206d | 0d | 13,025.86 | 02.03.03.04.03 | 10 días |
| 111 | 1.3.2 | **ARQUITECTURA** | 134d | 2026-07-28 | 2026-12-30 |  | 100d |  | 615,810.94 | 03 | 156 días |
| 112 | 1.3.2.1 | **MUROS Y TABIQUES DE ALBAÑILERIA** | 88d | 2026-07-28 | 2026-11-06 |  | 146d |  | 97,695.85 | 03.01 | 102 días |
| 113 | 1.3.2.1.1 | MURO DE LADRILLO KK MECANIZADO TIPO IV SOGA, MEZCLA 1:5, E=1.5cm | 88d | 2026-07-28 | 2026-11-06 | 60 | 145d |  | 97,695.85 | 03.01.01 | 102 días |
| 114 | 1.3.2.2 | **REVOQUES Y REVESTIMIENTOS** | 106d | 2026-08-05 | 2026-12-05 |  | 121d |  | 147,482.58 | 03.02 | 123 días |
| 115 | 1.3.2.2.1 | TARRAJEO RAYADO PRIMARIO, MEZCLA 1:5 | 47d | 2026-10-13 | 2026-12-05 | 104 | 71d | 0d | 22,309.6 | 03.02.01 | 54 días |
| 116 | 1.3.2.2.2 | TARRAJEO EN MUROS INTERIORES E=1.5cm, MEZCLA 1:5 | 24d | 2026-11-09 | 2026-12-05 | 115FF | 120d |  | 12,609.78 | 03.02.02 | 27 días |
| 117 | 1.3.2.2.3 | TARRAJEO EN MUROS EXTERIORES E=1.5cm, MEZCLA 1:5 | 31d | 2026-10-31 | 2026-12-05 | 115FF | 120d |  | 14,870.53 | 03.02.03 | 36 días |
| 118 | 1.3.2.2.4 | TARRAJEO EN COLUMNAS E=1.5cm, MEZCLA 1:5 | 106d | 2026-08-05 | 2026-12-05 | 115FF | 120d |  | 44,127.85 | 03.02.04 | 123 días |
| 119 | 1.3.2.2.5 | TARRAJEO EN VIGAS E=1.5cm, MEZCLA 1:5 | 60d | 2026-09-28 | 2026-12-05 | 115FF | 120d |  | 32,607.22 | 03.02.05 | 69 días |
| 120 | 1.3.2.2.6 | VESTIDURAS DE DERRAMES E=1.5cm, MEZCLA 1:5 | 40d | 2026-10-21 | 2026-12-05 | 115FF | 120d |  | 14,406 | 03.02.06 | 46 días |
| 121 | 1.3.2.2.7 | BRUÑAS DE 1cm | 10d | 2026-11-25 | 2026-12-05 | 115FF | 120d |  | 3,032.6 | 03.02.07 | 11 días |
| 122 | 1.3.2.2.8 | TARRAJEO EN FONDO DE ESCALERAS E=1.5cm, MEZCLA 1:5 | 6d | 2026-11-30 | 2026-12-05 | 115FF | 120d |  | 3,519 | 03.02.08 | 6 días |
| 123 | 1.3.2.3 | **CIELORRASOS** | 51d | 2026-10-08 | 2026-12-05 |  | 121d |  | 31,964.37 | 03.03 | 59 días |
| 124 | 1.3.2.3.1 | TARRAJEO EN CIELORRASOS E=1.5cm, MEZCLA 1:5 | 51d | 2026-10-08 | 2026-12-05 | 115FF | 120d |  | 31,964.37 | 03.03.01 | 59 días |
| 125 | 1.3.2.4 | **PISOS Y PAVIMENTOS** | 3d | 2026-09-03 | 2026-09-05 |  | 193d |  | 8,947.58 | 03.04 | 3 días |
| 126 | 1.3.2.4.1 | CONTRAPISO E=4.8cm, BASE E=3.8cm, MEZCLA 1:5 PASTA 1:2 | 3d | 2026-09-03 | 2026-09-05 | 85 | 192d | 0d | 8,947.58 | 03.04.01 | 3 días |
| 127 | 1.3.2.5 | **PISOS** | 24d | 2026-10-13 | 2026-11-09 |  | 144d |  | 48,779.8 | 03.05 | 28 días |
| 128 | 1.3.2.5.1 | PISO CERAMICO SIONA WHITE 45x45cm | 24d | 2026-10-13 | 2026-11-09 | 104 | 143d | 0d | 22,866.55 | 03.05.01 | 28 días |
| 129 | 1.3.2.5.2 | PISO CERAMICO COLOR HUESO DE 45x45cm | 4d | 2026-10-13 | 2026-10-16 | 128SS | 163d |  | 25,913.25 | 03.05.02 | 4 días |
| 130 | 1.3.2.6 | **ZOCALOS Y CONTRAZÓCALOS** | 23d | 2026-10-13 | 2026-11-07 |  | 145d |  | 58,544.81 | 03.06 | 26 días |
| 131 | 1.3.2.6.1 | ZOCALO CERAMICO SIONA WHITE DE 45x45cm | 23d | 2026-10-13 | 2026-11-07 | 128SS | 144d |  | 15,562.29 | 03.06.01 | 26 días |
| 132 | 1.3.2.6.2 | ZOCALO CERAMICO COLOR HUESO DE 45x45cm | 10d | 2026-10-13 | 2026-10-23 | 128SS | 157d |  | 6,538.06 | 03.06.02 | 11 días |
| 133 | 1.3.2.6.3 | ENCHAPE CON PIEDRA LAJA | 1d | 2026-10-13 | 2026-10-13 | 128SS | 166d |  | 3,981.34 | 03.06.03 | 1 día |
| 134 | 1.3.2.6.4 | CONTRAZOCALO CERAMICO COLOR HUESO DE H=0.225m | 1d | 2026-10-13 | 2026-10-13 | 128SS | 166d |  | 2,228.01 | 03.06.04 | 1 día |
| 135 | 1.3.2.6.5 | CONTRAZOCALO CERAMICO SIONA WHITE DE H=0.225m | 8d | 2026-10-13 | 2026-10-21 | 128SS | 159d |  | 30,235.11 | 03.06.05 | 9 días |

| ID | WBS | Task | Duration | Start | Finish | Predecessors | Total slack | Free slack | Cost | Text1 | Text2 |
| --- | --- | --- | --- | --- | --- | --- | --- | --- | --- | --- | --- |
| 136 | 1.3.2.7 | **COBERTURAS** | 23d | 2026-10-13 | 2026-11-07 |  | 145d |  | 32,125.92 | 03.07 | 26 días |
| 137 | 1.3.2.7.1 | SOBRECARGA CON IMPERMEABILIZANTE, E=2" MEZCLA 1:4 | 6d | 2026-10-13 | 2026-10-19 | 128SS | 161d |  | 12,392.32 | 03.07.01 | 7 días |
| 138 | 1.3.2.7.2 | PISO CERAMICO 45X45 CM | 23d | 2026-10-13 | 2026-11-07 | 128SS | 144d |  | 19,733.6 | 03.07.02 | 26 días |
| 139 | 1.3.2.8 | **CARPINTERÍA DE MADERA** | 7d | 2026-12-23 | 2026-12-30 |  | 100d |  | 8,597.04 | 03.08 | 8 días |
| 140 | 1.3.2.8.1 | PUERTA DE MADERA CONTRAPLACADA | 7d | 2026-12-23 | 2026-12-30 | 155FF | 99d |  | 8,597.04 | 03.08.01 | 8 días |
| 141 | 1.3.2.9 | **CARPINTERÍA METÁLICA Y HERRERÍA** | 14d | 2026-12-15 | 2026-12-30 |  | 100d |  | 139,034.39 | 03.09 | 16 días |
| 142 | 1.3.2.9.1 | PUERTA METALICA P-1 | 8d | 2026-12-22 | 2026-12-30 | 155FF | 99d |  | 4,442.91 | 03.09.01 | 9 días |
| 143 | 1.3.2.9.2 | DIVISION DE MELAMINE Y ESTRUCTURA DE ALUMINIO PARA SERVICIOS HIGIENICOS | 14d | 2026-12-15 | 2026-12-30 | 155FF | 99d |  | 24,016.98 | 03.09.02 | 16 días |
| 144 | 1.3.2.9.3 | BARANDAS METÁLICAS h=1.00m | 4d | 2026-12-26 | 2026-12-30 | 155FF | 99d |  | 31,810.05 | 03.09.03 | 5 días |
| 145 | 1.3.2.9.4 | CELOSIA DE CONCRETO VENTILACIÓN | 13d | 2026-12-16 | 2026-12-30 | 155FF | 99d |  | 55,728.02 | 03.09.04 | 15 días |
| 146 | 1.3.2.9.5 | CELOSIA METALICA ORNAMENTAL | 9d | 2026-12-21 | 2026-12-30 | 155FF | 99d |  | 23,036.43 | 03.09.05 | 10 días |
| 147 | 1.3.2.10 | **CERRAJERÍA** | 2d | 2026-12-29 | 2026-12-30 |  | 100d |  | 1,651.36 | 03.10 | 2 días |
| 148 | 1.3.2.10.1 | BISAGRA TIPO CAPUCHINO ALUMINIZADA 31/2" | 2d | 2026-12-29 | 2026-12-30 | 155FF | 99d |  | 755.56 | 03.10.01 | 2 días |
| 149 | 1.3.2.10.2 | CERRADURA PUERTAS EXTERIORES INC/INSTALACION | 1d | 2026-12-30 | 2026-12-30 | 155FF | 99d |  | 250.8 | 03.10.02 | 1 día |
| 150 | 1.3.2.10.3 | CERRADURA PUERTAS INTERIORES INC/INSTALACION | 1d | 2026-12-30 | 2026-12-30 | 155FF | 99d |  | 264.96 | 03.10.03 | 1 día |
| 151 | 1.3.2.10.4 | CERRADURA PARA BAÑOS | 1d | 2026-12-30 | 2026-12-30 | 155FF | 99d |  | 380.04 | 03.10.04 | 1 día |
| 152 | 1.3.2.11 | **VIDRIOS, CRISTALES Y SIMILARES** | 1d | 2026-12-30 | 2026-12-30 |  | 100d |  | 5,015.39 | 03.11 | 1 día |
| 153 | 1.3.2.11.1 | VENTANAS DE VIDRIO INCOLORO SISTEMA MODUGLAS 6mm | 1d | 2026-12-30 | 2026-12-30 | 155FF | 99d |  | 5,015.39 | 03.11.01 | 1 día |
| 154 | 1.3.2.12 | **PINTURA** | 21d | 2026-12-07 | 2026-12-30 |  | 72d |  | 35,971.85 | 03.12 | 24 días |
| 155 | 1.3.2.12.1 | PINTURA LATEX 2 MANOS EN CIELORRASO | 21d | 2026-12-07 | 2026-12-30 | 115 | 71d | 0d | 13,321.97 | 03.12.01 | 24 días |
| 156 | 1.3.2.12.2 | PINTURA LATEX 2 MANOS EN MUROS INTERIORES | 16d | 2026-12-07 | 2026-12-24 | 155SS | 104d |  | 12,160.94 | 03.12.02 | 18 días |
| 157 | 1.3.2.12.3 | PINTURA LATEX 2 MANOS EN MUROS EXTERIORES | 13d | 2026-12-07 | 2026-12-21 | 155SS | 107d |  | 9,145.5 | 03.12.03 | 15 días |
| 158 | 1.3.2.12.4 | PINTURA EN PUERTAS DE MADERA, BARNIZ, 2 MANOS | 1d | 2026-12-07 | 2026-12-07 | 155SS | 119d |  | 522.96 | 03.12.04 | 1 día |
| 159 | 1.3.2.12.5 | PINTURA EN BARANDAS ANTICORROSIVA Y ESMALTE 2 MANOS | 1d | 2026-12-07 | 2026-12-07 | 155SS | 119d |  | 820.48 | 03.12.05 | 1 día |

| ID | WBS | Task | Duration | Start | Finish | Predecessors | Total slack | Free slack | Cost | Text1 | Text2 |
| --- | --- | --- | --- | --- | --- | --- | --- | --- | --- | --- | --- |
| 160 | 1.3.3 | **INSTALACIONES SANITARIAS** | 147d | 2026-08-14 | 2027-02-01 |  | 72d |  | 165,520.61 | 04 | 172 días |
| 161 | 1.3.3.1 | **APARATOS SANITARIOS Y ACCESORIOS** | 14d | 2026-12-15 | 2026-12-30 |  | 84d |  | 31,446.88 | 04.01 | 16 días |
| 162 | 1.3.3.1.1 | **SUMINISTRO DE APARATOS SANITARIOS** | 14d | 2026-12-15 | 2026-12-30 |  | 84d |  | 25,842.96 | 04.01.01 | 16 días |
| 163 | 1.3.3.1.1.1 | INODORO NOVARA FLUX COLOR BLANCO | 2d | 2026-12-29 | 2026-12-30 | 155FF | 71d | 0d | 7,769 | 04.01.01.01 | 2 días |
| 164 | 1.3.3.1.1.2 | URINARIO CADET COLOR BLANCO | 1d | 2026-12-30 | 2026-12-30 | 163FF | 99d | 0d | 2,979.28 | 04.01.01.02 | 1 día |
| 165 | 1.3.3.1.1.3 | LAVATORIO OVALIN SONET COLOR BLANCO | 14d | 2026-12-15 | 2026-12-30 | 163FF | 99d |  | 4,589.2 | 04.01.01.03 | 16 días |
| 166 | 1.3.3.1.1.4 | LAVATORIO DE PARED COLOR BLANCO | 2d | 2026-12-29 | 2026-12-30 | 163FF | 99d |  | 253.8 | 04.01.01.04 | 2 días |
| 167 | 1.3.3.1.1.5 | LAVATORIO DE ACERO INOXIDABLE | 3d | 2026-12-28 | 2026-12-30 | 163FF | 99d |  | 10,251.68 | 04.01.01.05 | 3 días |
| 168 | 1.3.3.1.2 | **SUMINISTRO DE ACCESORIOS** | 2d | 2026-12-29 | 2026-12-30 | 163SS | 100d |  | 1,927.44 | 04.01.02 | 2 días |
| 169 | 1.3.3.1.2.1 | DISPENSADOR DE JABON | 2d | 2026-12-29 | 2026-12-30 | 163FF | 99d |  | 1,048.56 | 04.01.02.01 | 2 días |
| 170 | 1.3.3.1.2.2 | PAPELERA DE PLASTICO | 2d | 2026-12-29 | 2026-12-30 | 163FF | 99d |  | 878.88 | 04.01.02.02 | 2 días |
| 171 | 1.3.3.1.3 | **INSTALACIÓN DE APARATOS SANITARIOS** | 2d | 2026-12-29 | 2026-12-30 | 163SS | 100d |  | 2,978.86 | 04.01.03 | 2 días |
| 172 | 1.3.3.1.3.1 | INSTALACIÓN DE APARATOS SANITARIOS | 2d | 2026-12-29 | 2026-12-30 | 164FF | 99d |  | 2,978.86 | 04.01.03.01 | 2 días |
| 173 | 1.3.3.1.4 | **INSTALACIÓN DE ACCESORIOS** | 2d | 2026-12-29 | 2026-12-30 | 163SS | 100d |  | 697.62 | 04.01.04 | 2 días |
| 174 | 1.3.3.1.4.1 | INSTALACIÓN DE ACCESORIOS | 2d | 2026-12-29 | 2026-12-30 | 163FF | 99d |  | 697.62 | 04.01.04.01 | 2 días |
| 175 | 1.3.3.2 | **SISTEMA DE AGUA FRIA** | 104d | 2026-08-31 | 2026-12-29 |  | 101d |  | 32,682.57 | 04.02 | 121 días |
| 176 | 1.3.3.2.1 | **SALIDA DE AGUA FRÍA** | 5d | 2026-09-01 | 2026-09-05 |  | 199d |  | 7,980.47 | 04.02.01 | 5 días |
| 177 | 1.3.3.2.1.1 | SALIDA DE AGUA FRÍA - PVC 1/2" | 5d | 2026-09-01 | 2026-09-05 | 181FF | 198d |  | 2,674.35 | 04.02.01.01 | 5 días |
| 178 | 1.3.3.2.1.2 | SALIDA DE AGUA FRIA. - PVC 3/4" | 4d | 2026-09-02 | 2026-09-05 | 181FF | 198d |  | 3,120.32 | 04.02.01.02 | 4 días |
| 179 | 1.3.3.2.1.3 | SALIDA DE AGUA FRIA. - PVC 1" | 4d | 2026-09-02 | 2026-09-05 | 181FF | 198d |  | 2,185.8 | 04.02.01.03 | 4 días |
| 180 | 1.3.3.2.2 | **REDES DE DISTRIBUCIÓN AGUA FRIA** | 6d | 2026-08-31 | 2026-09-05 |  | 199d |  | 14,212.19 | 04.02.02 | 6 días |
| 181 | 1.3.3.2.2.1 | TUBERIA PVC CLASE 10 - 1/2" | 2d | 2026-09-04 | 2026-09-05 | 126FF | 198d | 0d | 1,835.48 | 04.02.02.01 | 2 días |
| 182 | 1.3.3.2.2.2 | TUBERIA PVC CLASE 10 - 3/4" | 1d | 2026-09-05 | 2026-09-05 | 181FF | 198d |  | 1,220.67 | 04.02.02.02 | 1 día |
| 183 | 1.3.3.2.2.3 | TUBERIA PVC CLASE 10 - 1" | 1d | 2026-09-05 | 2026-09-05 | 181FF | 198d |  | 273.29 | 04.02.02.03 | 1 día |
| 184 | 1.3.3.2.2.4 | TUBERIA PVC CLASE 10 - 1 1/2" | 6d | 2026-08-31 | 2026-09-05 | 181FF | 198d |  | 10,882.75 | 04.02.02.04 | 6 días |

| ID | WBS | Task | Duration | Start | Finish | Predecessors | Total slack | Free slack | Cost | Text1 | Text2 |
| --- | --- | --- | --- | --- | --- | --- | --- | --- | --- | --- | --- |
| 185 | 1.3.3.2.3 | **ACCESORIOS DE REDES DE AGUA FRIA** | 1d | 2026-09-05 | 2026-09-05 |  | 199d |  | 1,200 | 04.02.03 | 1 día |
| 186 | 1.3.3.2.3.1 | ACCESORIOS DE REDES DE AGUA FRIA | 1d | 2026-09-05 | 2026-09-05 | 181FF | 198d |  | 1,200 | 04.02.03.01 | 1 día |
| 187 | 1.3.3.2.4 | **VÁLVULAS** | 2d | 2026-12-28 | 2026-12-29 |  | 101d |  | 4,289.91 | 04.02.04 | 2 días |
| 188 | 1.3.3.2.4.1 | VALVULA COMPUERTA DE BRONCE 1/2" | 2d | 2026-12-28 | 2026-12-29 | 192FF | 100d | 0d | 2,285.7 | 04.02.04.01 | 2 días |
| 189 | 1.3.3.2.4.2 | VALVULA COMPUERTA DE BRONCE 1 1/2" | 1d | 2026-12-29 | 2026-12-29 | 188FF | 100d |  | 222.11 | 04.02.04.02 | 1 día |
| 190 | 1.3.3.2.4.3 | VALVULA CHECK DE BRONCE 1 1/2" | 1d | 2026-12-29 | 2026-12-29 | 163SS | 100d |  | 1,312.48 | 04.02.04.03 | 1 día |
| 191 | 1.3.3.2.4.4 | VALVULA FLOTADORA 1" | 1d | 2026-12-29 | 2026-12-29 | 163SS | 100d |  | 469.62 | 04.02.04.04 | 1 día |
| 192 | 1.3.3.2.5 | **ALMACENAMIENTO DE AGUA** | 1d | 2026-12-29 | 2026-12-29 |  | 101d | 0d | 5,000 | 04.02.05 | 1 día |
| 193 | 1.3.3.2.5.1 | TANQUE ELEVADO DE PVC ROTOPLAS O SIMILAR DE 2500lt, INCLUYE ACCESORIOS Y BASE APOYO | 1d | 2026-12-29 | 2026-12-29 | 163SS | 100d |  | 5,000 | 04.02.05.01 | 1 día |
| 194 | 1.3.3.3 | **SISTEMA CONTRA INCENDIO** | 128d | 2026-09-05 | 2027-02-01 |  | 72d |  | 55,384.11 | 04.03 | 150 días |
| 195 | 1.3.3.3.1 | **REDES DE ALIMENTACION** | 1d | 2026-09-05 | 2026-09-05 |  | 199d |  | 11,761.81 | 04.03.01 | 1 día |
| 196 | 1.3.3.3.1.1 | TUBERIA SCH 4" PARA SISTEMA CONTRA INCENDIO | 1d | 2026-09-05 | 2026-09-05 | 126FF | 198d | 0d | 5,094.8 | 04.03.01.01 | 1 día |
| 197 | 1.3.3.3.1.2 | TUBERIA SCH 21/2" PARA SISTEMA CONTRA INCENDIO | 1d | 2026-09-05 | 2026-09-05 | 196FF | 198d |  | 3,840.19 | 04.03.01.02 | 1 día |
| 198 | 1.3.3.3.1.3 | TUBERIA SCH 11/4" PARA SISTEMA CONTRA INCENDIO | 1d | 2026-09-05 | 2026-09-05 | 196FF | 198d |  | 2,826.82 | 04.03.01.03 | 1 día |
| 199 | 1.3.3.3.2 | **ACCESORIOS DE REDES CONTRA INCENDIO** | 1d | 2026-09-05 | 2026-09-05 |  | 199d |  | 5,300 | 04.03.02 | 1 día |
| 200 | 1.3.3.3.2.1 | ACCESORIOS DE REDES CONTRA INCENDIO | 1d | 2026-09-05 | 2026-09-05 | 196FF | 198d |  | 5,300 | 04.03.02.01 | 1 día |
| 201 | 1.3.3.3.3 | **SUMINISTRO E INSTALACION DE GABINETE CONTRA INCENDIO** | 3d | 2026-12-26 | 2026-12-29 |  | 101d |  | 1,611.72 | 04.03.03 | 4 días |
| 202 | 1.3.3.3.3.1 | SUMINISTRO DE GABINETES CONTRA INCENDIOS | 3d | 2026-12-26 | 2026-12-29 | 204FF | 100d |  | 1,611.72 | 04.03.03.01 | 4 días |
| 203 | 1.3.3.3.4 | **VALVULAS** | 1d | 2026-12-29 | 2026-12-29 |  | 101d |  | 19,223.1 | 04.03.04 | 1 día |
| 204 | 1.3.3.3.4.1 | VALVULA COMPUERTA DE BRONCE 1 1/4" | 1d | 2026-12-29 | 2026-12-29 | 163SS | 100d | 0d | 728.16 | 04.03.04.01 | 1 día |
| 205 | 1.3.3.3.4.2 | VALVULA COMPUERTA DE BRONCE 2 1/2" | 1d | 2026-12-29 | 2026-12-29 | 163SS | 100d |  | 4,585.12 | 04.03.04.02 | 1 día |
| 206 | 1.3.3.3.4.3 | VALVULA DE COMPUERTA DE BRONCE 4" | 1d | 2026-12-29 | 2026-12-29 | 163SS | 100d |  | 3,912.56 | 04.03.04.03 | 1 día |
| 207 | 1.3.3.3.4.4 | VALVULA CHECK DE BRONCE 4" | 1d | 2026-12-29 | 2026-12-29 | 163SS | 100d |  | 5,945.04 | 04.03.04.04 | 1 día |
| 208 | 1.3.3.3.4.5 | VALVULA DE AIRE 2" INC. ACCESORIOS | 1d | 2026-12-29 | 2026-12-29 | 163SS | 100d |  | 2,625.92 | 04.03.04.05 | 1 día |
| 209 | 1.3.3.3.4.6 | SIAMESA MODELO POSTE 4"x 2 1/2" | 1d | 2026-12-29 | 2026-12-29 | 163SS | 100d |  | 1,426.3 | 04.03.04.06 | 1 día |

| ID | WBS | Task | Duration | Start | Finish | Predecessors | Total slack | Free slack | Cost | Text1 | Text2 |
| --- | --- | --- | --- | --- | --- | --- | --- | --- | --- | --- | --- |
| 210 | 1.3.3.3.5 | **EQUIPOS Y OTRAS INSTALACIONES** | 30d | 2026-12-29 | 2027-02-01 | 163SS | 72d |  | 17,487.48 | 04.03.05 | 35 días |
| 211 | 1.3.3.3.5.1 | BOMBA JOKEY DE 2HP | 1d | 2026-12-29 | 2026-12-29 | 163SS | 100d |  | 6,900 | 04.03.05.01 | 1 día |
| 212 | 1.3.3.3.5.2 | EQUIPO DE BOMBEO, ELECTROBOMBAS 20 HP | 30d | 2026-12-29 | 2027-02-01 | 163SS | 71d |  | 10,587.48 | 04.03.05.02 | 35 días |
| 213 | 1.3.3.4 | **SISTEMA DE DRENAJE PLUVIAL** | 2d | 2026-09-04 | 2026-09-05 |  | 199d |  | 2,696.99 | 04.04 | 2 días |
| 214 | 1.3.3.4.1 | **REDES DE DISTRIBUCIÓN DRENAJE PLUVIAL** | 2d | 2026-09-04 | 2026-09-05 |  | 199d |  | 1,696.99 | 04.04.01 | 2 días |
| 215 | 1.3.3.4.1.1 | TUBERIA PVC SAL 4" P/LLUVIAS | 2d | 2026-09-04 | 2026-09-05 | 223FF | 198d |  | 1,696.99 | 04.04.01.01 | 2 días |
| 216 | 1.3.3.4.2 | **ACCESORIOS DE DRENAJE PLUVIAL** | 1d | 2026-09-05 | 2026-09-05 |  | 199d |  | 1,000 | 04.04.02 | 1 día |
| 217 | 1.3.3.4.2.1 | ACCESORIOS DE DRENAJE PLUVIAL | 1d | 2026-09-05 | 2026-09-05 | 223FF | 198d |  | 1,000 | 04.04.02.01 | 1 día |
| 218 | 1.3.3.5 | **DESAGÜE Y VENTILACIÓN** | 119d | 2026-08-14 | 2026-12-30 |  | 100d |  | 43,310.06 | 04.05 | 139 días |
| 219 | 1.3.3.5.1 | **SALIDAS DE DESAGÜE** | 4d | 2026-09-02 | 2026-09-05 |  | 199d |  | 12,431.04 | 04.05.01 | 4 días |
| 220 | 1.3.3.5.1.1 | SALIDA DE DESAGUE PVC SAL 2" | 1d | 2026-09-05 | 2026-09-05 | 223FF | 198d |  | 9,916.8 | 04.05.01.01 | 1 día |
| 221 | 1.3.3.5.1.2 | SALIDA DE DESAGUE PVC SAL 4" | 4d | 2026-09-02 | 2026-09-05 | 223FF | 198d |  | 2,514.24 | 04.05.01.02 | 4 días |
| 222 | 1.3.3.5.2 | **REDES DE DERIVACIÓN** | 20d | 2026-08-14 | 2026-09-05 |  | 199d |  | 24,922.73 | 04.05.02 | 23 días |
| 223 | 1.3.3.5.2.1 | TUBERIA PVC SAL PARA DESAGUE 2" | 20d | 2026-08-14 | 2026-09-05 | 126FF | 198d | 0d | 17,662.13 | 04.05.02.01 | 23 días |
| 224 | 1.3.3.5.2.2 | TUBERIA PVC SAL PARA DESAGUE 4" | 5d | 2026-09-01 | 2026-09-05 | 223FF | 198d |  | 4,371.84 | 04.05.02.02 | 5 días |
| 225 | 1.3.3.5.2.3 | TUBERIA PVC SAL PARA VENTILACION 2" | 4d | 2026-09-02 | 2026-09-05 | 223FF | 198d |  | 2,888.76 | 04.05.02.03 | 4 días |
| 226 | 1.3.3.5.3 | **ACCESORIOS DE REDES COLECTORAS** | 9d | 2026-12-21 | 2026-12-30 |  | 100d |  | 5,294.16 | 04.05.03 | 10 días |
| 227 | 1.3.3.5.3.1 | SUMIDERO DE BRONCE 2" | 9d | 2026-12-21 | 2026-12-30 | 163FF | 99d |  | 3,193.68 | 04.05.03.01 | 10 días |
| 228 | 1.3.3.5.3.2 | REGISTRO ROSCADO 4" | 6d | 2026-12-24 | 2026-12-30 | 163FF | 99d |  | 2,100.48 | 04.05.03.02 | 7 días |
| 229 | 1.3.3.5.4 | **CÁMARAS DE INSPECCIÓN** | 1d | 2026-09-05 | 2026-09-05 |  | 199d |  | 662.13 | 04.05.04 | 1 día |
| 230 | 1.3.3.5.4.1 | CAJA DE REGISTRO DE 12"x24" DE CONCRETO INC/TAPA | 1d | 2026-09-05 | 2026-09-05 | 223FF | 198d |  | 662.13 | 04.05.04.01 | 1 día |
| 231 | 1.3.4 | **INSTALACIONES ELECTRICAS; TELECOMUNICACIONES Y ESPECIALES** | 134d | 2026-07-28 | 2026-12-30 |  | 100d |  | 276,913.51 | 05 | 156 días |
| 232 | 1.3.4.1 | **MOVIMIENTO DE TIERRAS** | 13d | 2026-07-28 | 2026-08-11 |  | 221d |  | 5,085.35 | 05.01 | 15 días |
| 233 | 1.3.4.1.1 | TRAZO, NIVELES Y REPLANTEO PRELIMINAR | 1d | 2026-07-28 | 2026-07-28 | 62 | 220d | 0d | 756.16 | 05.01.01 | 1 día |
| 234 | 1.3.4.1.2 | EXCAVACION DE ZANJA PARA RED DE TUBERIA | 6d | 2026-07-29 | 2026-08-04 | 233 | 220d | 0d | 917.24 | 05.01.02 | 7 días |
| 235 | 1.3.4.1.3 | RELLENO CON MATERIAL PROPIO COMPACTADO C/EQUIPO | 3d | 2026-08-05 | 2026-08-07 | 234 | 220d | 0d | 1,176 | 05.01.03 | 3 días |
| 236 | 1.3.4.1.4 | ACARREO MANUAL DE MATERIAL DE RELLENO | 3d | 2026-08-08 | 2026-08-11 | 235 | 220d |  | 1,425.29 | 05.01.04 | 4 días |
| 237 | 1.3.4.1.5 | ACARREO MANUAL DE MATERIAL EXCEDENTE | 1d | 2026-08-08 | 2026-08-08 | 235 | 221d | 0d | 159.92 | 05.01.05 | 1 día |
| 238 | 1.3.4.1.6 | ELIMINACION DE MATERIAL EXCEDENTE CON EQUIPO | 1d | 2026-08-10 | 2026-08-10 | 237 | 221d |  | 202.32 | 05.01.06 | 1 día |
| 239 | 1.3.4.1.7 | EXCAVACION DE HUECO PARA PUESTA A TIERRA | 1d | 2026-07-29 | 2026-07-29 | 234SS | 231d |  | 224.21 | 05.01.07 | 1 día |
| 240 | 1.3.4.1.8 | EXCAVACION DE HUECO PARA BUZON DE ENERGIA | 1d | 2026-07-29 | 2026-07-29 | 234SS | 231d |  | 224.21 | 05.01.08 | 1 día |

| ID | WBS | Task | Duration | Start | Finish | Predecessors | Total slack | Free slack | Cost | Text1 | Text2 |
| --- | --- | --- | --- | --- | --- | --- | --- | --- | --- | --- | --- |
| 241 | 1.3.4.2 | **SALIDAS PARA ALUMBRADO, TOMACORRIENTES, FUERZA Y SEÑALES DÉBILES** | 105d | 2026-08-31 | 2026-12-30 |  | 100d |  | 207,785.19 | 05.02 | 122 días |
| 242 | 1.3.4.2.1 | **SALIDA** | 6d | 2026-08-31 | 2026-09-05 |  | 199d |  | 29,222.44 | 05.02.01 | 6 días |
| 243 | 1.3.4.2.1.1 | SALIDA DE ALUMBRADO EN TECHO | 4d | 2026-09-02 | 2026-09-05 | 257FF | 198d |  | 4,961.6 | 05.02.01.01 | 4 días |
| 244 | 1.3.4.2.1.2 | SALIDA DE INTERRUPTOR SIMPLE | 5d | 2026-09-01 | 2026-09-05 | 257FF | 198d |  | 6,212.76 | 05.02.01.02 | 5 días |
| 245 | 1.3.4.2.1.3 | SALIDA PARA TOMACORRIENTE BIPOLAR DOBLE + L.T. (TENSION COMERCIAL) | 3d | 2026-09-03 | 2026-09-05 | 257FF | 198d |  | 10,145.28 | 05.02.01.03 | 3 días |
| 246 | 1.3.4.2.1.4 | CAJA OCTOGONAL PESADA | 1d | 2026-09-05 | 2026-09-05 | 257FF | 198d |  | 3,117.1 | 05.02.01.04 | 1 día |
| 247 | 1.3.4.2.1.5 | CAJA RECTANGULAR PESADA | 6d | 2026-08-31 | 2026-09-05 | 257FF | 198d |  | 3,346 | 05.02.01.05 | 6 días |
| 248 | 1.3.4.2.1.6 | CAJA CUADRADA DE F°G° DE PASE 100 DE 100X100 | 1d | 2026-09-05 | 2026-09-05 | 257FF | 198d |  | 217.5 | 05.02.01.06 | 1 día |
| 249 | 1.3.4.2.1.7 | CAJA CUADRADA DE F°G° DE PASE 150 DE 150X150 | 1d | 2026-09-05 | 2026-09-05 | 257FF | 198d |  | 568.35 | 05.02.01.07 | 1 día |
| 250 | 1.3.4.2.1.8 | CAJA CUADRADA DE F°G° DE PASE 200 DE 200X200 | 1d | 2026-09-05 | 2026-09-05 | 257FF | 198d |  | 568.35 | 05.02.01.08 | 1 día |
| 251 | 1.3.4.2.1.9 | SALIDA PARA DETECTOR SENSOR DE ALARMAS C/INCENDIO | 1d | 2026-09-05 | 2026-09-05 | 257FF | 198d |  | 85.5 | 05.02.01.09 | 1 día |
| 252 | 1.3.4.2.2 | **CANALIZACIONES, CONDUCTOS O TUBERÍAS** | 7d | 2026-09-05 | 2026-09-12 |  | 193d |  | 5,931.16 | 05.02.02 | 8 días |
| 253 | 1.3.4.2.2.1 | TUBERIA PVC-SAP (ELECTRICA) DE Ø 20 MM | 7d | 2026-09-05 | 2026-09-12 | 257SS | 192d |  | 4,253.06 | 05.02.02.01 | 8 días |
| 254 | 1.3.4.2.2.2 | TUBERIA PVC-SAP (ELECTRICA) DE Ø 25 MM | 1d | 2026-09-05 | 2026-09-05 | 257SS | 198d |  | 268.65 | 05.02.02.02 | 1 día |
| 255 | 1.3.4.2.2.3 | TUBERIA PVC-SAP (ELECTRICA) DE Ø 35 MM | 1d | 2026-09-05 | 2026-09-05 | 257SS | 198d |  | 310.25 | 05.02.02.03 | 1 día |
| 256 | 1.3.4.2.2.4 | TUBERIA PVC-SAP (ELECTRICA) DE Ø 40 MM | 1d | 2026-09-05 | 2026-09-05 | 257SS | 198d |  | 233.2 | 05.02.02.04 | 1 día |
| 257 | 1.3.4.2.2.5 | TUBERIA PVC-SAP (ELECTRICA) DE Ø 100 MM | 1d | 2026-09-05 | 2026-09-05 | 126FF | 192d | 0d | 866 | 05.02.02.05 | 1 día |
| 258 | 1.3.4.2.3 | **CONDUCTORES Y CABLES DE ENERGÍA EN TUBERÍAS** | 8d | 2026-12-22 | 2026-12-30 |  | 100d |  | 168,808.42 | 05.02.03 | 9 días |
| 259 | 1.3.4.2.3.1 | ALIMENTADOR A TABLEROS GENERALES 3 - 1 X 16 MM2 + 1 X 16 MM2 (N) NYY | 1d | 2026-12-30 | 2026-12-30 | 155FF | 99d |  | 6,320.92 | 05.02.03.01 | 1 día |
| 260 | 1.3.4.2.3.2 | ALIMENTADOR PARA SALIDA DE FUERZA TRIFASICA CABLE DE 25 MM2 | 5d | 2026-12-25 | 2026-12-30 | 155FF | 99d |  | 65,993.92 | 05.02.03.02 | 6 días |
| 261 | 1.3.4.2.3.3 | ALIMENTADOR PARA SALIDA DE FUERZA TRIFASICA CABLE DE 10 MM2 | 8d | 2026-12-22 | 2026-12-30 | 155FF | 99d |  | 30,769.5 | 05.02.03.03 | 9 días |
| 262 | 1.3.4.2.3.4 | ALIMENTADOR A SUBTABLEROS DE DISTRIBUCION 2 - 1 x 10 mm2 | 6d | 2026-12-24 | 2026-12-30 | 155FF | 99d |  | 3,445.44 | 05.02.03.04 | 7 días |
| 263 | 1.3.4.2.3.5 | ALIMENTADOR A TABLEROS DE STANDS 2X10 MM2 NYY | 4d | 2026-12-26 | 2026-12-30 | 155FF | 99d |  | 13,928.2 | 05.02.03.05 | 5 días |
| 264 | 1.3.4.2.3.6 | CABLE DE COBRE DESNUDO 1 X 35 mm2 TEMPLE BLANDO P/TIERRA | 3d | 2026-12-28 | 2026-12-30 | 155FF | 99d |  | 48,350.44 | 05.02.03.06 | 3 días |

| ID | WBS | Task | Duration | Start | Finish | Predecessors | Total slack | Cost | Text1 | Text2 |
| --- | --- | --- | --- | --- | --- | --- | --- | --- | --- | --- |
| 265 | 1.3.4.2.4 | **TABLERO DE DISTRIBUCIÓN, DISPOSITIVOS DE MANIOBRA Y PROTECCION** | 2d | 2026-12-29 | 2026-12-30 |  | 100d | 3,823.17 | 05.02.04 | 2 días |
| 266 | 1.3.4.2.4.1 | TABLERO GENERAL DE DISTRIBUCIÓN TG.D - 10G | 1d | 2026-12-30 | 2026-12-30 | 155FF | 99d | 676.07 | 05.02.04.01 | 1 día |
| 267 | 1.3.4.2.4.2 | TABLERO GENERAL DE DISTRIBUCIÓN TG.D - 20G | 1d | 2026-12-30 | 2026-12-30 | 155FF | 99d | 611.22 | 05.02.04.02 | 1 día |
| 268 | 1.3.4.2.4.3 | TABLERO GENERAL DE DISTRIBUCIÓN TG.D - 30G | 1d | 2026-12-30 | 2026-12-30 | 155FF | 99d | 552.92 | 05.02.04.03 | 1 día |
| 269 | 1.3.4.2.4.4 | SUBTABLERO DE DISTRIBUCION ST.D - 40 Y ST. D - 50 | 1d | 2026-12-30 | 2026-12-30 | 155FF | 99d | 669.64 | 05.02.04.04 | 1 día |
| 270 | 1.3.4.2.4.5 | TABLERO ELECTRICO DE STANDS GENERALES | 2d | 2026-12-29 | 2026-12-30 | 155FF | 99d | 1,313.32 | 05.02.04.05 | 2 días |
| 271 | 1.3.4.3 | **ARTEFACTOS DE ALUMBRADO** | 1d | 2026-12-30 | 2026-12-30 |  | 100d | 10,258.57 | 05.03 | 1 día |
| 272 | 1.3.4.3.1 | ARTEFACTO FLUORESCENTE RAS 2X36 W, REJILLA | 1d | 2026-12-30 | 2026-12-30 | 155FF | 99d | 2,182.6 | 05.03.01 | 1 día |
| 273 | 1.3.4.3.2 | ARTEFACTO FLUORESCENTE HERMETICO 2X36 W | 1d | 2026-12-30 | 2026-12-30 | 155FF | 99d | 2,040.85 | 05.03.02 | 1 día |
| 274 | 1.3.4.3.3 | LUZ DE EMERGENCIA 2X20 W 2 HORAS DE AUTONOMIA | 1d | 2026-12-30 | 2026-12-30 | 155FF | 99d | 3,124.2 | 05.03.03 | 1 día |
| 275 | 1.3.4.3.4 | ARTEFACTO BRAQUETE MODELO RSP TC-DEL 2X18 W, EXTERIOR | 1d | 2026-12-30 | 2026-12-30 | 155FF | 99d | 1,139.76 | 05.03.04 | 1 día |
| 276 | 1.3.4.3.5 | LUMINARIA SPOT GALAXIE 2X26 W; INC. LAMPARAS | 1d | 2026-12-30 | 2026-12-30 | 155FF | 99d | 1,256.8 | 05.03.05 | 1 día |
| 277 | 1.3.4.3.6 | INSTALACION DE SOKET INC. FOCO AHORRADOR TIPO GLOBO 1X18 W | 1d | 2026-12-30 | 2026-12-30 | 155FF | 99d | 514.36 | 05.03.06 | 1 día |
| 278 | 1.3.4.4 | **INSTALACIÓN DEL SISTEMA DE PUESTA A TIERRA** | 2d | 2026-12-29 | 2026-12-30 |  | 100d | 5,216.4 | 05.04 | 2 días |
| 279 | 1.3.4.4.1 | POZO DE PUESTA A TIERRA <= 15 OHMS | 2d | 2026-12-29 | 2026-12-30 | 155FF | 99d | 5,216.4 | 05.04.01 | 2 días |
| 280 | 1.3.4.5 | **OTROS** | 3d | 2026-12-28 | 2026-12-30 |  | 100d | 10,838.09 | 05.05 | 3 días |
| 281 | 1.3.4.5.1 | BANCO DE MEDIDORES | 1d | 2026-12-30 | 2026-12-30 | 155FF | 99d | 101.98 | 05.05.01 | 1 día |
| 282 | 1.3.4.5.2 | BUZON DE ENERGIA ARMADO DE 1.00 X 1.00 M | 1d | 2026-12-30 | 2026-12-30 | 155FF | 99d | 5,277.87 | 05.05.02 | 1 día |
| 283 | 1.3.4.5.3 | **PRUEBA Y ENERGIZACION** | 3d | 2026-12-28 | 2026-12-30 |  | 100d | 5,458.24 | 05.05.03 | 3 días |
| 284 | 1.3.4.5.3.1 | PRUEBAS ELECTRICAS | 3d | 2026-12-28 | 2026-12-30 | 155FF | 99d | 5,201.97 | 05.05.03.01 | 3 días |
| 285 | 1.3.4.5.3.2 | INSTALACION DE MEDIDOR DE ENERGIA ELECTRICA | 1d | 2026-12-30 | 2026-12-30 | 155FF | 99d | 256.27 | 05.05.03.02 | 1 día |
| 286 | 1.3.4.6 | **INSTALACION DE SISTEMA CONTRAINCENDIOS** | 5d | 2026-12-25 | 2026-12-30 |  | 100d | 37,729.91 | 05.06 | 6 días |
| 287 | 1.3.4.6.1 | INSTALACION DE CABLE CONTRA INCENDIO | 5d | 2026-12-25 | 2026-12-30 | 155FF | 99d | 6,247.51 | 05.06.01 | 6 días |
| 288 | 1.3.4.6.2 | SUMINISTRO INSTALACION DE DETECTOR DE HUMO | 2d | 2026-12-29 | 2026-12-30 | 155FF | 99d | 6,768.6 | 05.06.02 | 2 días |
| 289 | 1.3.4.6.3 | SUMINISTRO INSTALACION DE DETECTOR DE TEMPERATURA | 2d | 2026-12-29 | 2026-12-30 | 155FF | 99d | 7,781.6 | 05.06.03 | 2 días |
| 290 | 1.3.4.6.4 | SUMINISTRO E INSTALACION LUZ ESTROBOSCOPICA C/INCENDIO | 1d | 2026-12-30 | 2026-12-30 | 155FF | 99d | 3,656.76 | 05.06.04 | 1 día |
| 291 | 1.3.4.6.5 | SUMINISTRO E INSTALACION ESTACION MANUAL C/INCENDIO | 1d | 2026-12-30 | 2026-12-30 | 155FF | 99d | 5,485.14 | 05.06.05 | 1 día |
| 292 | 1.3.4.6.6 | SUMINISTRO E INSTALACION DE CENTRAL DE ALARMA CONTRAINCENDIO | 2d | 2026-12-29 | 2026-12-30 | 155FF | 99d | 7,417.74 | 05.06.06 | 2 días |
| 293 | 1.3.4.6.7 | CONFIGURACION DE SISTEMAS DE ALARMAS CONTRA INCENDIOS SENSOR INTELIGENTE | 1d | 2026-12-30 | 2026-12-30 | 155FF | 99d | 372.56 | 05.06.07 | 1 día |

| ID | WBS | Task | Duration | Start | Finish | Predecessors | Total slack | Free slack | Constraint | Cost | Text1 | Text2 |
| --- | --- | --- | --- | --- | --- | --- | --- | --- | --- | --- | --- | --- |
| 294 | 1.3.5 | **EQUIPAMIENTO** | 15d | 2026-12-14 | 2026-12-30 |  | 100d |  |  | 10,000 | 06 | 17 días |
| 295 | 1.3.5.1 | EQUIPAMIENTO DE PATIO DE COMIDAS Y ZONA DE JUGOS | 15d | 2026-12-14 | 2026-12-30 | 155FF | 99d |  |  | 10,000 | 06.01 | 17 días |
| 296 | 1.4 | **BLOQUE N°2** | 305d | 2026-05-06 | 2027-04-25 |  | 0d |  |  | 3,221,311.42 |  | 355 días |
| 297 | 1.4.1 | **ESTRUCTURAS** | 261d | 2026-05-06 | 2027-03-05 |  | 44d |  |  | 1,392,185.41 | 07 | 304 días |
| 298 | 1.4.1.1 | **MOVIMIENTO DE TIERRAS** | 25d | 2026-05-06 | 2026-06-03 |  | 222d |  |  | 104,836.89 | 07.01 | 29 días |
| 299 | 1.4.1.1.1 | EXCAVACION MANUAL DE ZANJAS Y ZAPATAS | 25d | 2026-05-06 | 2026-06-03 | 38 | 221d | 0d |  | 69,254.83 | 07.01.01 | 29 días |
| 300 | 1.4.1.1.2 | RELLENO COMPACTADO CON MATERIAL PROPIO 7.0HP | 25d | 2026-05-06 | 2026-06-03 | 299FF | 221d | 0d |  | 23,642.59 | 07.01.02 | 29 días |
| 301 | 1.4.1.1.3 | ELIMINACION DE MATERIAL EXCEDENTE C/EQUIPO | 7d | 2026-05-27 | 2026-06-03 | 300FF | 221d | 0d |  | 11,939.47 | 07.01.03 | 8 días |
| 302 | 1.4.1.2 | **OBRAS DE CONCRETO SIMPLE** | 137d | 2026-05-12 | 2026-10-17 |  | 163d |  |  | 27,642.69 | 07.02 | 159 días |
| 303 | 1.4.1.2.1 | CONCRETO PARA CIMIENTOS CICLOPEO 1:10 + 30% P.G. | 2d | 2026-10-16 | 2026-10-17 | 311 | 162d |  |  | 8,586.24 | 07.02.01 | 2 días |
| 304 | 1.4.1.2.2 | CONCRETO PARA SOLADOS E=0.10m C:H, 1:12 | 3d | 2026-05-12 | 2026-05-14 | 307FF | 253d | 0d |  | 5,978.7 | 07.02.02 | 3 días |
| 305 | 1.4.1.2.3 | CONCRETO PARA SOBRECIMIENTOS CICLOPEO 1:8 + 25% P.M. | 1d | 2026-10-16 | 2026-10-16 | 311 | 163d | 0d |  | 2,818.41 | 07.02.03 | 1 día |
| 306 | 1.4.1.2.4 | ENCOFRADO Y DESENCOFRADO NORMAL PARA SOBRECIMIENTO | 3d | 2026-10-13 | 2026-10-16 | 305SF | 164d |  |  | 4,401.43 | 07.02.04 | 4 días |
| 307 | 1.4.1.2.5 | CONCRETO PARA FALSO PISO E=4" MEZCLA 1:8 C:H | 1d | 2026-05-14 | 2026-05-14 | 299SS+7d | 253d | 0d |  | 5,857.91 | 07.02.05 | 1 día |
| 308 | 1.4.1.3 | **OBRAS DE CONCRETO ARMADO** | 253d | 2026-05-15 | 2027-03-05 |  | 44d |  |  | 1,259,705.83 | 07.03 | 295 días |
| 309 | 1.4.1.3.1 | **PRIMER NIVEL** | 189d | 2026-05-15 | 2026-12-21 |  | 108d |  |  | 539,233.66 | 07.03.01 | 221 días |
| 310 | 1.4.1.3.1.1 | **ZAPATAS** | 17d | 2026-10-03 | 2026-10-22 |  | 0d |  |  | 99,445 | 07.03.01.01 | 20 días |
| 311 | 1.4.1.3.1.1.1 | CONCRETO f'c=210Kg/cm2 PARA ZAPATAS | 4d | 2026-10-12 | 2026-10-15 | 313 | 162d | 0d |  | 58,309.02 | 07.03.01.01.01 | 4 días |
| 312 | 1.4.1.3.1.1.2 | ENCOFRADO Y DESENCOFRADO NORMAL PARA ZAPATAS | 13d | 2026-10-03 | 2026-10-22 | 313SS | 0d |  |  | 11,773.48 | 07.03.01.01.02 | 20 días |
| 313 | 1.4.1.3.1.1.3 | ACERO GRADO 60, EN ZAPATAS | 7d | 2026-10-03 | 2026-10-10 | 106 | 0d |  |  | 29,362.5 | 07.03.01.01.03 | 8 días |
| 314 | 1.4.1.3.1.2 | **MUROS DE CONTENCION** | 43d | 2026-05-15 | 2026-07-03 |  | 254d |  |  | 154,490.67 | 07.03.01.02 | 50 días |
| 315 | 1.4.1.3.1.2.1 | CONCRETO f'c=210Kg/cm2 PARA MUROS DE CONTENCION | 15d | 2026-06-02 | 2026-07-03 | 317SS+15d | 253d |  |  | 77,346.79 | 07.03.01.02.01 | 32 días |
| 316 | 1.4.1.3.1.2.2 | ENCOFRADO Y DESENCOFRADO NORMAL PARA MUROS DE CONTENCION | 26d | 2026-05-19 | 2026-06-25 | 317SS+3d | 260d |  | start no earlier than 2026-05-07 | 28,138.88 | 07.03.01.02.02 | 38 días |
| 317 | 1.4.1.3.1.2.3 | ACERO GRADO 60, EN MUROS DE CONTENCION | 20d | 2026-05-15 | 2026-06-15 | 304 | 253d | 0d |  | 49,005 | 07.03.01.02.03 | 32 días |

| ID | WBS | Task | Duration | Start | Finish | Predecessors | Total slack | Free slack | Cost | Text1 | Text2 |
| --- | --- | --- | --- | --- | --- | --- | --- | --- | --- | --- | --- |
| 318 | 1.4.1.3.1.3 | **COLUMNAS** | 20d | 2026-10-23 | 2026-11-14 |  | 0d |  | 79,558.94 | 07.03.01.03 | 23 días |
| 319 | 1.4.1.3.1.3.1 | CONCRETO f'c=210Kg/cm2 PARA COLUMNAS | 4d | 2026-11-04 | 2026-11-07 | 321 | 144d |  | 9,578.65 | 07.03.01.03.01 | 4 días |
| 320 | 1.4.1.3.1.3.2 | ENCOFRADO Y DESENCOFRADO NORMAL PARA COLUMNAS | 14d | 2026-10-26 | 2026-11-14 | 321SS+2d | 0d |  | 33,731.44 | 07.03.01.03.02 | 20 días |
| 321 | 1.4.1.3.1.3.3 | ACERO GRADO 60, EN COLUMNAS | 10d | 2026-10-23 | 2026-11-03 | 312 | 0d |  | 36,248.85 | 07.03.01.03.03 | 12 días |
| 322 | 1.4.1.3.1.4 | **VIGAS** | 20d | 2026-11-16 | 2026-12-08 |  | 108d |  | 39,645.84 | 07.03.01.04 | 23 días |
| 323 | 1.4.1.3.1.4.1 | CONCRETO f'c=210Kg/cm2 PARA VIGAS | 4d | 2026-11-27 | 2026-12-01 | 325 | 124d |  | 8,659.48 | 07.03.01.04.01 | 5 días |
| 324 | 1.4.1.3.1.4.2 | ENCOFRADO Y DESENCOFRADO NORMAL PARA VIGAS | 16d | 2026-11-16 | 2026-12-08 | 320 | 107d | 0d | 15,207.09 | 07.03.01.04.02 | 23 días |
| 325 | 1.4.1.3.1.4.3 | ACERO GRADO 60, EN VIGAS | 10d | 2026-11-16 | 2026-11-26 | 324SS | 124d | 0d | 15,779.27 | 07.03.01.04.03 | 11 días |
| 326 | 1.4.1.3.1.5 | **LOSAS** | 17d | 2026-11-16 | 2026-12-04 |  | 0d |  | 140,229.28 | 07.03.01.05 | 19 días |
| 327 | 1.4.1.3.1.5.1 | **LOSAS ALIGERADAS** | 17d | 2026-11-16 | 2026-12-04 |  | 0d |  | 140,229.28 | 07.03.01.05.01 | 19 días |
| 328 | 1.4.1.3.1.5.1.1 | CONCRETO f'c=210Kg/cm2 PARA LOSAS ALIGERADAS | 4d | 2026-11-24 | 2026-11-27 | 331 | 127d |  | 7,524.11 | 07.03.01.05.01.01 | 4 días |
| 329 | 1.4.1.3.1.5.1.2 | ENCOFRADO Y DESENCOFRADO NORMAL PARA LOSAS ALIGERADAS | 13d | 2026-11-16 | 2026-12-04 | 320 | 0d |  | 11,755.4 | 07.03.01.05.01.02 | 19 días |
| 330 | 1.4.1.3.1.5.1.3 | LADRILLO PARA LOSA ALIGERADA 0.20x0.30x0.30m | 4d | 2026-11-16 | 2026-11-19 | 331SS | 134d |  | 50,608.29 | 07.03.01.05.01.03 | 4 días |
| 331 | 1.4.1.3.1.5.1.4 | ACERO GRADO 60, EN LOSAS ALIGERADAS | 7d | 2026-11-16 | 2026-11-23 | 329SS | 127d | 0d | 70,341.48 | 07.03.01.05.01.04 | 8 días |
| 332 | 1.4.1.3.1.6 | **ESCALERAS** | 11d | 2026-12-09 | 2026-12-21 |  | 108d |  | 25,863.93 | 07.03.01.06 | 13 días |
| 333 | 1.4.1.3.1.6.1 | CONCRETO f'c=210Kg/cm2 PARA ESCALERAS | 3d | 2026-12-18 | 2026-12-21 | 335 | 107d |  | 2,640.03 | 07.03.01.06.01 | 4 días |
| 334 | 1.4.1.3.1.6.2 | ENCOFRADO Y DESENCOFRADO NORMAL PARA ESCALERAS | 7d | 2026-12-09 | 2026-12-16 | 324 | 107d | 0d | 1,956.02 | 07.03.01.06.02 | 8 días |
| 335 | 1.4.1.3.1.6.3 | ACERO GRADO 60, EN ESCALERAS | 8d | 2026-12-09 | 2026-12-17 | 334SS | 107d | 0d | 21,267.88 | 07.03.01.06.03 | 9 días |
| 336 | 1.4.1.3.2 | **SEGUNDO NIVEL** | 51d | 2026-12-05 | 2027-02-02 |  | 0d |  | 392,905.82 | 07.03.02 | 60 días |
| 337 | 1.4.1.3.2.1 | **COLUMNAS** | 20d | 2026-12-05 | 2026-12-28 |  | 0d |  | 125,958.69 | 07.03.02.01 | 24 días |
| 338 | 1.4.1.3.2.1.1 | CONCRETO f'c=210Kg/cm2 PARA COLUMNAS | 4d | 2026-12-17 | 2026-12-21 | 340 | 107d |  | 11,640.88 | 07.03.02.01.01 | 5 días |
| 339 | 1.4.1.3.2.1.2 | ENCOFRADO Y DESENCOFRADO NORMAL PARA COLUMNAS | 15d | 2026-12-07 | 2026-12-28 | 340SS+1d | 0d |  | 41,820.11 | 07.03.02.01.02 | 22 días |
| 340 | 1.4.1.3.2.1.3 | ACERO GRADO 60, EN COLUMNAS | 10d | 2026-12-05 | 2026-12-16 | 329 | 0d |  | 72,497.7 | 07.03.02.01.03 | 12 días |
| 341 | 1.4.1.3.2.2 | **VIGAS** | 17d | 2026-12-29 | 2027-01-16 |  | 71d |  | 84,540.52 | 07.03.02.02 | 19 días |
| 342 | 1.4.1.3.2.2.1 | CONCRETO f'c=210Kg/cm2 PARA VIGAS | 3d | 2027-01-07 | 2027-01-09 | 344 | 90d |  | 19,546.88 | 07.03.02.02.01 | 3 días |
| 343 | 1.4.1.3.2.2.2 | ENCOFRADO Y DESENCOFRADO NORMAL PARA VIGAS | 14d | 2026-12-29 | 2027-01-16 | 339 | 70d | 0d | 33,435.09 | 07.03.02.02.02 | 19 días |
| 344 | 1.4.1.3.2.2.3 | ACERO GRADO 60, EN VIGAS | 7d | 2026-12-30 | 2027-01-06 | 343SS+1d | 90d | 0d | 31,558.55 | 07.03.02.02.03 | 8 días |

| ID | WBS | Task | Duration | Start | Finish | Predecessors | Total slack | Free slack | Cost | Text1 | Text2 |
| --- | --- | --- | --- | --- | --- | --- | --- | --- | --- | --- | --- |
| 345 | 1.4.1.3.2.3 | **LOSAS** | 17d | 2026-12-29 | 2027-01-16 |  | 0d |  | 152,411.9 | 07.03.02.03 | 19 días |
| 346 | 1.4.1.3.2.3.1 | **LOSAS ALIGERADAS** | 17d | 2026-12-29 | 2027-01-16 |  | 0d |  | 152,411.9 | 07.03.02.03.01 | 19 días |
| 347 | 1.4.1.3.2.3.1.1 | CONCRETO f'c=210Kg/cm2 PARA LOSAS ALIGERADAS | 3d | 2027-01-07 | 2027-01-09 | 350 | 91d |  | 24,227.44 | 07.03.02.03.01.01 | 3 días |
| 348 | 1.4.1.3.2.3.1.2 | ENCOFRADO Y DESENCOFRADO NORMAL PARA LOSAS ALIGERADAS | 14d | 2026-12-29 | 2027-01-16 | 339 | 0d |  | 37,838.23 | 07.03.02.03.01.02 | 19 días |
| 349 | 1.4.1.3.2.3.1.3 | LADRILLO PARA LOSA ALIGERADA 0.20x0.30x0.30m | 7d | 2026-12-30 | 2027-01-06 | 348SS+1d | 94d |  | 20,004.75 | 07.03.02.03.01.03 | 8 días |
| 350 | 1.4.1.3.2.3.1.4 | ACERO GRADO 60, EN LOSAS ALIGERADAS | 7d | 2026-12-30 | 2027-01-06 | 348SS+1d | 91d | 0d | 70,341.48 | 07.03.02.03.01.04 | 8 días |
| 351 | 1.4.1.3.2.4 | **ESCALERAS** | 14d | 2027-01-18 | 2027-02-02 |  | 71d |  | 29,994.71 | 07.03.02.04 | 16 días |
| 352 | 1.4.1.3.2.4.1 | CONCRETO f'c=210Kg/cm2 PARA ESCALERAS | 4d | 2027-01-22 | 2027-01-26 | 354 | 76d |  | 7,865.53 | 07.03.02.04.01 | 5 días |
| 353 | 1.4.1.3.2.4.2 | ENCOFRADO Y DESENCOFRADO NORMAL PARA ESCALERAS | 10d | 2027-01-18 | 2027-02-02 | 343 | 70d | 0d | 861.3 | 07.03.02.04.02 | 16 días |
| 354 | 1.4.1.3.2.4.3 | ACERO GRADO 60, EN ESCALERAS | 4d | 2027-01-18 | 2027-01-21 | 353SS | 76d | 0d | 21,267.88 | 07.03.02.04.03 | 4 días |
| 355 | 1.4.1.3.3 | **TERCER NIVEL** | 41d | 2027-01-18 | 2027-03-05 |  | 0d |  | 327,566.35 | 07.03.03 | 47 días |
| 356 | 1.4.1.3.3.1 | **COLUMNAS** | 22d | 2027-01-18 | 2027-02-11 |  | 0d |  | 125,958.69 | 07.03.03.01 | 25 días |
| 357 | 1.4.1.3.3.1.1 | CONCRETO f'c=210Kg/cm2 PARA COLUMNAS | 4d | 2027-02-01 | 2027-02-04 | 359 | 69d |  | 11,640.88 | 07.03.03.01.01 | 4 días |
| 358 | 1.4.1.3.3.1.2 | ENCOFRADO Y DESENCOFRADO NORMAL PARA COLUMNAS | 17d | 2027-01-19 | 2027-02-11 | 359SS+1d | 0d |  | 41,820.11 | 07.03.03.01.02 | 24 días |
| 359 | 1.4.1.3.3.1.3 | ACERO GRADO 60, EN COLUMNAS | 12d | 2027-01-18 | 2027-01-30 | 348 | 0d |  | 72,497.7 | 07.03.03.01.03 | 13 días |
| 360 | 1.4.1.3.3.2 | **VIGAS** | 19d | 2027-02-12 | 2027-03-05 |  | 44d |  | 49,195.51 | 07.03.03.02 | 22 días |
| 361 | 1.4.1.3.3.2.1 | CONCRETO f'c=210Kg/cm2 PARA VIGAS | 3d | 2027-02-24 | 2027-02-26 | 363 | 50d |  | 6,099.93 | 07.03.03.02.01 | 3 días |
| 362 | 1.4.1.3.3.2.2 | ENCOFRADO Y DESENCOFRADO NORMAL PARA VIGAS | 16d | 2027-02-12 | 2027-03-05 | 358 | 44d | 0d | 11,537.03 | 07.03.03.02.02 | 22 días |
| 363 | 1.4.1.3.3.2.3 | ACERO GRADO 60, EN VIGAS | 10d | 2027-02-12 | 2027-02-23 | 362SS | 49d | 0d | 31,558.55 | 07.03.03.02.03 | 12 días |
| 364 | 1.4.1.3.3.3 | **LOSAS** | 19d | 2027-02-12 | 2027-03-05 |  | 0d |  | 152,412.15 | 07.03.03.03 | 22 días |
| 365 | 1.4.1.3.3.3.1 | **LOSAS ALIGERADAS** | 19d | 2027-02-12 | 2027-03-05 |  | 0d |  | 152,412.15 | 07.03.03.03.01 | 22 días |
| 366 | 1.4.1.3.3.3.1.1 | CONCRETO f'c=210Kg/cm2 PARA LOSAS ALIGERADAS | 3d | 2027-02-24 | 2027-02-26 | 369 | 21d | 0d | 24,227.44 | 07.03.03.03.01.01 | 3 días |
| 367 | 1.4.1.3.3.3.1.2 | ENCOFRADO Y DESENCOFRADO NORMAL PARA LOSAS ALIGERADAS | 13d | 2027-02-12 | 2027-03-05 | 358 | 0d |  | 37,838.23 | 07.03.03.03.01.02 | 22 días |
| 368 | 1.4.1.3.3.3.1.3 | LADRILLO PARA LOSA ALIGERADA 0.20x0.30x0.30m | 3d | 2027-02-16 | 2027-02-18 | 369SS | 56d |  | 20,005 | 07.03.03.03.01.03 | 3 días |
| 369 | 1.4.1.3.3.3.1.4 | ACERO GRADO 60, EN LOSAS ALIGERADAS | 7d | 2027-02-16 | 2027-02-23 | 367SS+3d | 21d | 0d | 70,341.48 | 07.03.03.03.01.04 | 8 días |

| ID | WBS | Task | Duration | Start | Finish | Predecessors | Total slack | Free slack | Cost | Text1 | Text2 |
| --- | --- | --- | --- | --- | --- | --- | --- | --- | --- | --- | --- |
| 370 | 1.4.2 | **ARQUITECTURA** | 229d | 2026-08-03 | 2027-04-25 |  | 0d |  | 950,031.8 | 08 | 266 días |
| 371 | 1.4.2.1 | **MUROS Y TABIQUES DE ALBAÑILERIA** | 80d | 2026-12-07 | 2027-03-09 |  | 41d |  | 132,686 | 08.01 | 93 días |
| 372 | 1.4.2.1.1 | MURO DE LADRILLO KK MECANIZADO TIPO IV SOGA, MEZCLA 1:5, E=1.5cm | 80d | 2026-12-07 | 2027-03-09 | 367FF+3d | 41d |  | 132,686 | 08.01.01 | 93 días |
| 373 | 1.4.2.2 | **REVOQUES Y REVESTIMIENTOS** | 188d | 2026-08-03 | 2027-03-09 |  | 41d |  | 252,632.87 | 08.02 | 219 días |
| 374 | 1.4.2.2.1 | TARRAJEO RAYADO PRIMARIO, MEZCLA 1:5 | 90d | 2026-11-25 | 2027-03-09 | 367FF+3d | 0d |  | 43,279.21 | 08.02.01 | 105 días |
| 375 | 1.4.2.2.2 | TARRAJEO EN MUROS INTERIORES E=1.5cm, MEZCLA 1:5 | 83d | 2026-12-03 | 2027-03-09 | 367FF+3d | 41d |  | 43,497.5 | 08.02.02 | 97 días |
| 376 | 1.4.2.2.3 | TARRAJEO EN MUROS EXTERIORES E=1.5cm, MEZCLA 1:5 | 83d | 2026-12-03 | 2027-03-09 | 367FF+3d | 41d |  | 40,718.57 | 08.02.03 | 97 días |
| 377 | 1.4.2.2.4 | TARRAJEO EN COLUMNAS E=1.5cm, MEZCLA 1:5 | 188d | 2026-08-03 | 2027-03-09 | 367FF+3d | 41d |  | 78,252.13 | 08.02.04 | 219 días |
| 378 | 1.4.2.2.5 | TARRAJEO EN VIGAS E=1.5cm, MEZCLA 1:5 | 69d | 2026-12-19 | 2027-03-09 | 367FF+3d | 41d |  | 37,560.84 | 08.02.05 | 81 días |
| 379 | 1.4.2.2.6 | VESTIDURAS DE DERRAMES E=1.5cm, MEZCLA 1:5 | 20d | 2027-02-15 | 2027-03-09 | 367FF+3d | 41d |  | 7,096.33 | 08.02.06 | 23 días |
| 380 | 1.4.2.2.7 | TARRAJEO EN FONDO DE ESCALERAS E=1.5cm, MEZCLA 1:5 | 4d | 2027-03-05 | 2027-03-09 | 367FF+3d | 41d |  | 2,228.29 | 08.02.07 | 5 días |
| 381 | 1.4.2.3 | **CIELORRASOS** | 112d | 2026-11-13 | 2027-03-23 |  | 29d |  | 69,729.78 | 08.03 | 131 días |
| 382 | 1.4.2.3.1 | TARRAJEO EN CIELORRASOS E=1.5cm, MEZCLA 1:5 | 112d | 2026-11-13 | 2027-03-23 | 367FF+15d | 29d |  | 69,729.78 | 08.03.01 | 131 días |
| 383 | 1.4.2.4 | **PISOS Y PAVIMENTOS** | 11d | 2027-01-18 | 2027-01-29 |  | 29d |  | 35,848.38 | 08.04 | 12 días |
| 384 | 1.4.2.4.1 | CONTRAPISO E=4.8cm, BASE E=3.8cm, MEZCLA 1:5 PASTA 1:2 | 11d | 2027-01-18 | 2027-01-29 | 348 | 29d | 0d | 35,848.38 | 08.04.01 | 12 días |
| 385 | 1.4.2.5 | **PISOS** | 45d | 2027-01-30 | 2027-03-23 |  | 29d |  | 75,409.25 | 08.05 | 53 días |
| 386 | 1.4.2.5.1 | PISO CERAMICO SIONA WHITE 45x45cm | 45d | 2027-01-30 | 2027-03-23 | 384 | 29d | 0d | 75,409.25 | 08.05.01 | 53 días |
| 387 | 1.4.2.6 | **ZOCALOS Y CONTRAZÓCALOS** | 80d | 2026-12-21 | 2027-03-23 |  | 29d |  | 103,876.24 | 08.06 | 93 días |
| 388 | 1.4.2.6.1 | ZOCALO CERAMICO SIONA WHITE DE 45x45cm | 80d | 2026-12-21 | 2027-03-23 | 386FF | 29d |  | 103,876.24 | 08.06.01 | 93 días |
| 389 | 1.4.2.7 | **CARPINTERÍA DE MADERA** | 6d | 2027-03-03 | 2027-03-09 |  | 41d |  | 7,737.34 | 08.07 | 7 días |
| 390 | 1.4.2.7.1 | PUERTA DE MADERA CONTRAPLACADA | 6d | 2027-03-03 | 2027-03-09 | 374FF | 41d |  | 7,737.34 | 08.07.01 | 7 días |
| 391 | 1.4.2.8 | **CARPINTERÍA METÁLICA Y HERRERÍA** | 15d | 2027-02-20 | 2027-03-09 |  | 41d |  | 139,059.57 | 08.08 | 18 días |
| 392 | 1.4.2.8.1 | PUERTA DE REJA METALICA | 1d | 2027-03-09 | 2027-03-09 | 374FF | 41d |  | 5,957.06 | 08.08.01 | 1 día |
| 393 | 1.4.2.8.2 | DIVISION DE MELAMINE Y ESTRUCTURA DE ALUMINIO PARA SERVICIOS HIGIENICOS | 15d | 2027-02-20 | 2027-03-09 | 374FF | 41d |  | 26,200.34 | 08.08.02 | 18 días |
| 394 | 1.4.2.8.3 | BARANDAS METÁLICAS h=1.00m | 10d | 2027-02-26 | 2027-03-09 | 374FF | 41d |  | 88,347.44 | 08.08.03 | 12 días |
| 395 | 1.4.2.8.4 | REJILLA DE VENTILACION | 1d | 2027-03-09 | 2027-03-09 | 374FF | 41d |  | 746.73 | 08.08.04 | 1 día |
| 396 | 1.4.2.8.5 | CELOSIA METALICA ORNAMENTAL | 7d | 2027-03-02 | 2027-03-09 | 374FF | 41d |  | 17,808 | 08.08.05 | 8 días |

| ID | WBS | Task | Duration | Start | Finish | Predecessors | Total slack | Constraint | Cost | Text1 | Text2 |
| --- | --- | --- | --- | --- | --- | --- | --- | --- | --- | --- | --- |
| 397 | 1.4.2.9 | **CERRAJERÍA** | 9d | 2027-02-27 | 2027-03-09 |  | 41d |  | 9,727.74 | 08.09 | 11 días |
| 398 | 1.4.2.9.1 | BISAGRA TIPO CAPUCHINO ALUMINIZADA 31/2" | 5d | 2027-03-04 | 2027-03-09 | 374FF | 41d |  | 1,743.6 | 08.09.01 | 6 días |
| 399 | 1.4.2.9.2 | CERRADURA PUERTAS EXTERIORES INC/INSTALACION | 9d | 2027-02-27 | 2027-03-09 | 374FF | 41d |  | 5,643 | 08.09.02 | 11 días |
| 400 | 1.4.2.9.3 | CERRADURA PUERTAS INTERIORES INC/INSTALACION | 2d | 2027-03-08 | 2027-03-09 | 374FF | 41d |  | 1,391.04 | 08.09.03 | 2 días |
| 401 | 1.4.2.9.4 | CERRADURA PARA BAÑOS | 2d | 2027-03-08 | 2027-03-09 | 374FF | 41d |  | 950.1 | 08.09.04 | 2 días |
| 402 | 1.4.2.10 | **VIDRIOS, CRISTALES Y SIMILARES** | 8d | 2027-03-01 | 2027-03-09 |  | 41d |  | 23,563.28 | 08.10 | 9 días |
| 403 | 1.4.2.10.1 | VENTANAS DE VIDRIO INCOLORO SISTEMA MODUGLAS 6mm | 4d | 2027-03-05 | 2027-03-09 | 374FF | 41d |  | 22,436.28 | 08.10.01 | 5 días |
| 404 | 1.4.2.10.2 | ESPEJOS | 8d | 2027-03-01 | 2027-03-09 | 374FF | 41d |  | 1,127 | 08.10.02 | 9 días |
| 405 | 1.4.2.11 | **PINTURA** | 41d | 2027-03-10 | 2027-04-25 |  | 0d |  | 90,502.04 | 08.11 | 47 días |
| 406 | 1.4.2.11.1 | PINTURA LATEX 2 MANOS EN CIELORRASO | 41d | 2027-03-10 | 2027-04-25 | 374 | 0d |  | 31,806.92 | 08.11.01 | 47 días |
| 407 | 1.4.2.11.2 | PINTURA LATEX 2 MANOS EN MUROS INTERIORES | 30d | 2027-03-23 | 2027-04-25 | 406FF | 0d |  | 34,957.67 | 08.11.02 | 34 días |
| 408 | 1.4.2.11.3 | PINTURA LATEX 2 MANOS EN MUROS EXTERIORES | 28d | 2027-03-25 | 2027-04-25 | 406FF | 0d |  | 20,517.36 | 08.11.03 | 32 días |
| 409 | 1.4.2.11.4 | PINTURA EN PUERTAS DE MADERA, BARNIZ, 2 MANOS | 2d | 2027-04-24 | 2027-04-25 | 406FF | 0d |  | 941.33 | 08.11.04 | 2 días |
| 410 | 1.4.2.11.5 | PINTURA EN BARANDAS ANTICORROSIVA Y ESMALTE 2 MANOS | 1d | 2027-04-25 | 2027-04-25 | 406FF | 0d |  | 2,278.76 | 08.11.05 | 1 día |
| 411 | 1.4.2.12 | **VARIOS** | 10d | 2027-02-26 | 2027-03-09 |  | 41d |  | 9,259.31 | 08.12 | 12 días |
| 412 | 1.4.2.12.1 | MESA DE CONCRETO ACABADO EN CUARZO GRIS PARA OVALIN H=20cm | 10d | 2027-02-26 | 2027-03-09 | 374FF | 41d |  | 9,259.31 | 08.12.01 | 12 días |
| 413 | 1.4.3 | **INSTALACIONES SANITARIAS** | 141d | 2026-11-13 | 2027-04-25 |  | 0d |  | 531,066.71 | 09 | 164 días |
| 414 | 1.4.3.1 | **APARATOS SANITARIOS Y ACCESORIOS** | 12d | 2027-04-13 | 2027-04-25 |  | 0d |  | 31,592.9 | 09.01 | 13 días |
| 415 | 1.4.3.1.1 | **SUMINISTRO DE APARATOS SANITARIOS** | 12d | 2027-04-13 | 2027-04-25 |  | 0d |  | 25,596.3 | 09.01.01 | 13 días |
| 416 | 1.4.3.1.1.1 | INODORO NOVARA FLUX COLOR BLANCO | 3d | 2027-04-23 | 2027-04-25 | 408FF | 0d | finish no earlier than 2027-04-25 | 9,322.8 | 09.01.01.01 | 3 días |
| 417 | 1.4.3.1.1.2 | URINARIO CADET COLOR BLANCO | 2d | 2027-04-24 | 2027-04-25 | 408FF | 0d |  | 4,468.92 | 09.01.01.02 | 2 días |
| 418 | 1.4.3.1.1.3 | LAVATORIO OVALIN SONET COLOR BLANCO | 12d | 2027-04-13 | 2027-04-25 | 408FF | 0d |  | 3,933.6 | 09.01.01.03 | 13 días |
| 419 | 1.4.3.1.1.4 | LAVATORIO DE PARED COLOR BLANCO | 5d | 2027-04-21 | 2027-04-25 | 408FF | 0d |  | 634.5 | 09.01.01.04 | 5 días |
| 420 | 1.4.3.1.1.5 | LAVATORIO DE ACERO INOXIDABLE | 2d | 2027-04-24 | 2027-04-25 | 408FF | 0d |  | 7,236.48 | 09.01.01.05 | 2 días |

| ID | WBS | Task | Duration | Start | Finish | Predecessors | Total slack | Free slack | Cost | Text1 | Text2 |
| --- | --- | --- | --- | --- | --- | --- | --- | --- | --- | --- | --- |
| 421 | 1.4.3.1.2 | **SUMINISTRO DE ACCESORIOS** | 3d | 2027-04-23 | 2027-04-25 |  | 0d |  | 2,351.83 | 09.01.02 | 3 días |
| 422 | 1.4.3.1.2.1 | DISPENSADOR DE JABON | 3d | 2027-04-23 | 2027-04-25 | 408FF | 0d |  | 1,747.6 | 09.01.02.01 | 3 días |
| 423 | 1.4.3.1.2.2 | PAPELERA DE PLASTICO | 2d | 2027-04-24 | 2027-04-25 | 408FF | 0d |  | 604.23 | 09.01.02.02 | 2 días |
| 424 | 1.4.3.1.3 | **INSTALACIÓN DE APARATOS SANITARIOS** | 9d | 2027-04-16 | 2027-04-25 |  | 0d |  | 2,978.86 | 09.01.03 | 10 días |
| 425 | 1.4.3.1.3.1 | INSTALACIÓN DE APARATOS SANITARIOS | 9d | 2027-04-16 | 2027-04-25 | 408FF | 0d |  | 2,978.86 | 09.01.03.01 | 10 días |
| 426 | 1.4.3.1.4 | **INSTALACIÓN DE ACCESORIOS** | 2d | 2027-04-24 | 2027-04-25 |  | 0d |  | 665.91 | 09.01.04 | 2 días |
| 427 | 1.4.3.1.4.1 | INSTALACIÓN DE ACCESORIOS | 2d | 2027-04-24 | 2027-04-25 | 408FF | 0d |  | 665.91 | 09.01.04.01 | 2 días |
| 428 | 1.4.3.2 | **SISTEMA DE AGUA FRIA** | 74d | 2027-01-25 | 2027-04-20 |  | 5d |  | 82,876.41 | 09.02 | 86 días |
| 429 | 1.4.3.2.1 | **SALIDA DE AGUA FRÍA** | 5d | 2027-01-25 | 2027-01-30 |  | 74d |  | 10,489.25 | 09.02.01 | 6 días |
| 430 | 1.4.3.2.1.1 | SALIDA DE AGUA FRÍA - PVC 1/2" | 5d | 2027-01-25 | 2027-01-30 | 435FF | 74d | 0d | 2,674.35 | 09.02.01.01 | 6 días |
| 431 | 1.4.3.2.1.2 | SALIDA DE AGUA FRIA. - PVC 3/4" | 4d | 2027-01-26 | 2027-01-30 | 430FF | 74d |  | 2,535.26 | 09.02.01.02 | 5 días |
| 432 | 1.4.3.2.1.3 | SALIDA DE AGUA FRIA. - PVC 1" | 4d | 2027-01-26 | 2027-01-30 | 430FF | 74d |  | 2,185.8 | 09.02.01.03 | 5 días |
| 433 | 1.4.3.2.1.4 | SALIDA DE AGUA FRIA. - PVC 1 1/2" | 4d | 2027-01-26 | 2027-01-30 | 430FF | 74d |  | 3,093.84 | 09.02.01.04 | 5 días |
| 434 | 1.4.3.2.2 | **REDES DE DISTRIBUCIÓN AGUA FRIA** | 2d | 2027-01-28 | 2027-01-30 |  | 74d |  | 6,725.06 | 09.02.02 | 3 días |
| 435 | 1.4.3.2.2.1 | TUBERIA PVC CLASE 10 - 1/2" | 2d | 2027-01-28 | 2027-01-30 | 386SF | 74d | 0d | 1,316.31 | 09.02.02.01 | 3 días |
| 436 | 1.4.3.2.2.2 | TUBERIA PVC CLASE 10 - 3/4" | 2d | 2027-01-28 | 2027-01-30 | 435FF | 74d |  | 2,014.72 | 09.02.02.02 | 3 días |
| 437 | 1.4.3.2.2.3 | TUBERIA PVC CLASE 10 - 1" | 1d | 2027-01-29 | 2027-01-30 | 435FF | 74d |  | 508.03 | 09.02.02.03 | 2 días |
| 438 | 1.4.3.2.2.4 | TUBERIA PVC CLASE 10 - 1 1/2" | 2d | 2027-01-28 | 2027-01-30 | 435FF | 74d |  | 2,886 | 09.02.02.04 | 3 días |
| 439 | 1.4.3.2.3 | **ACCESORIOS DE REDES DE AGUA FRIA** | 1d | 2027-01-29 | 2027-01-30 |  | 74d |  | 1,200 | 09.02.03 | 2 días |
| 440 | 1.4.3.2.3.1 | ACCESORIOS DE REDES DE AGUA FRIA | 1d | 2027-01-29 | 2027-01-30 | 435FF | 74d |  | 1,200 | 09.02.03.01 | 2 días |
| 441 | 1.4.3.2.4 | **VÁLVULAS** | 5d | 2027-04-15 | 2027-04-20 |  | 5d |  | 43,580.88 | 09.02.04 | 6 días |
| 442 | 1.4.3.2.4.1 | VALVULA COMPUERTA DE BRONCE 1/2" | 4d | 2027-04-16 | 2027-04-20 | 407FF-5d | 5d |  | 3,007.5 | 09.02.04.01 | 5 días |
| 443 | 1.4.3.2.4.2 | VALVULA COMPUERTA DE BRONCE 1" | 3d | 2027-04-17 | 2027-04-20 | 407FF-5d | 5d |  | 2,438.82 | 09.02.04.02 | 4 días |
| 444 | 1.4.3.2.4.3 | VALVULA COMPUERTA DE BRONCE 1 1/2" | 2d | 2027-04-19 | 2027-04-20 | 407FF-5d | 5d |  | 3,331.65 | 09.02.04.03 | 2 días |
| 445 | 1.4.3.2.4.4 | VALVULA CHECK DE BRONCE 1" | 2d | 2027-04-19 | 2027-04-20 | 407FF-5d | 5d |  | 1,840.2 | 09.02.04.04 | 2 días |
| 446 | 1.4.3.2.4.5 | VALVULA CHECK DE BRONCE 1 1/2" | 3d | 2027-04-17 | 2027-04-20 | 407FF-5d | 5d |  | 27,562.08 | 09.02.04.05 | 4 días |
| 447 | 1.4.3.2.4.6 | VALVULA FLOTADORA 1" | 5d | 2027-04-15 | 2027-04-20 | 407FF-5d | 5d |  | 5,400.63 | 09.02.04.06 | 6 días |

| ID | WBS | Task | Duration | Start | Finish | Predecessors | Total slack | Free slack | Cost | Text1 | Text2 |
| --- | --- | --- | --- | --- | --- | --- | --- | --- | --- | --- | --- |
| 448 | 1.4.3.2.5 | **ALMACENAMIENTO DE AGUA** | 1d | 2027-04-20 | 2027-04-20 |  | 5d |  | 5,000 | 09.02.05 | 1 día |
| 449 | 1.4.3.2.5.1 | TANQUE ELEVADO DE PVC ROTOPLAS O SIMILAR DE 2500lt, INCLUYE ACCESORIOS Y BASE APOYO | 1d | 2027-04-20 | 2027-04-20 | 407FF-5d | 5d |  | 5,000 | 09.02.05.01 | 1 día |
| 450 | 1.4.3.2.6 | **EQUIPOS Y OTRAS INSTALACIONES** | 45d | 2027-02-27 | 2027-04-20 |  | 5d |  | 15,881.22 | 09.02.06 | 53 días |
| 451 | 1.4.3.2.6.1 | EQUIPO DE BOMBEO, ELECTROBOMBAS 1.4 HP | 45d | 2027-02-27 | 2027-04-20 | 407FF-5d | 5d |  | 15,881.22 | 09.02.06.01 | 53 días |
| 452 | 1.4.3.3 | **SISTEMA CONTRA INCENDIO** | 104d | 2026-12-21 | 2027-04-20 |  | 5d |  | 273,071.24 | 09.03 | 121 días |
| 453 | 1.4.3.3.1 | **REDES DE ALIMENTACION** | 1d | 2027-01-29 | 2027-01-30 |  | 74d |  | 18,705.89 | 09.03.01 | 2 días |
| 454 | 1.4.3.3.1.1 | TUBERIA SCH 4" PARA SISTEMA CONTRA INCENDIO | 1d | 2027-01-29 | 2027-01-30 | 435FF | 74d | 0d | 8,592.36 | 09.03.01.01 | 2 días |
| 455 | 1.4.3.3.1.2 | TUBERIA SCH 21/2" PARA SISTEMA CONTRA INCENDIO | 1d | 2027-01-29 | 2027-01-30 | 454FF | 74d |  | 6,282.47 | 09.03.01.02 | 2 días |
| 456 | 1.4.3.3.1.3 | TUBERIA SCH 11/4" PARA SISTEMA CONTRA INCENDIO | 1d | 2027-01-29 | 2027-01-30 | 454FF | 74d |  | 3,831.06 | 09.03.01.03 | 2 días |
| 457 | 1.4.3.3.2 | **ACCESORIOS DE REDES CONTRA INCENDIO** | 35d | 2026-12-21 | 2027-01-30 |  | 74d |  | 185,500 | 09.03.02 | 41 días |
| 458 | 1.4.3.3.2.1 | ACCESORIOS DE REDES CONTRA INCENDIO | 35d | 2026-12-21 | 2027-01-30 | 454FF | 74d |  | 185,500 | 09.03.02.01 | 41 días |
| 459 | 1.4.3.3.3 | **SUMINISTRO E INSTALACION DE GABINETE CONTRA INCENDIO** | 5d | 2027-01-25 | 2027-01-30 |  | 74d |  | 2,686.2 | 09.03.03 | 6 días |
| 460 | 1.4.3.3.3.1 | SUMINISTRO DE GABINETES CONTRA INCENDIOS | 5d | 2027-01-25 | 2027-01-30 | 454FF | 74d |  | 2,686.2 | 09.03.03.01 | 6 días |
| 461 | 1.4.3.3.4 | **VALVULAS** | 2d | 2027-04-19 | 2027-04-20 |  | 5d |  | 48,691.67 | 09.03.04 | 2 días |
| 462 | 1.4.3.3.4.1 | VALVULA COMPUERTA DE BRONCE 1 1/4" | 1d | 2027-04-20 | 2027-04-20 | 407FF-5d | 5d |  | 970.88 | 09.03.04.01 | 1 día |
| 463 | 1.4.3.3.4.2 | VALVULA COMPUERTA DE BRONCE 2 1/2" | 1d | 2027-04-20 | 2027-04-20 | 407FF-5d | 5d |  | 5,158.26 | 09.03.04.02 | 1 día |
| 464 | 1.4.3.3.4.3 | VALVULA DE COMPUERTA DE BRONCE 4" | 1d | 2027-04-20 | 2027-04-20 | 407FF-5d | 5d |  | 9,781.4 | 09.03.04.03 | 1 día |
| 465 | 1.4.3.3.4.4 | VALVULA CHECK DE BRONCE 4" | 1d | 2027-04-20 | 2027-04-20 | 407FF-5d | 5d |  | 14,862.6 | 09.03.04.04 | 1 día |
| 466 | 1.4.3.3.4.5 | VALVULA DE AIRE 2" INC. ACCESORIOS | 2d | 2027-04-19 | 2027-04-20 | 407FF-5d | 5d |  | 7,221.28 | 09.03.04.05 | 2 días |
| 467 | 1.4.3.3.4.6 | SIAMESA MODELO POSTE 4"x 2 1/2" | 2d | 2027-04-19 | 2027-04-20 | 407FF-5d | 5d |  | 10,697.25 | 09.03.04.06 | 2 días |
| 468 | 1.4.3.3.5 | **EQUIPOS Y OTRAS INSTALACIONES** | 30d | 2027-03-17 | 2027-04-20 |  | 5d |  | 17,487.48 | 09.03.05 | 35 días |
| 469 | 1.4.3.3.5.1 | BOMBA JOKEY DE 2HP | 1d | 2027-04-20 | 2027-04-20 | 407FF-5d | 5d |  | 6,900 | 09.03.05.01 | 1 día |
| 470 | 1.4.3.3.5.2 | EQUIPO DE BOMBEO, ELECTROBOMBAS 20 HP | 30d | 2027-03-17 | 2027-04-20 | 407FF-5d | 5d |  | 10,587.48 | 09.03.05.02 | 35 días |
| 471 | 1.4.3.4 | **SISTEMA DE DRENAJE PLUVIAL** | 1d | 2027-04-20 | 2027-04-20 |  | 5d |  | 2,024.75 | 09.04 | 1 día |
| 472 | 1.4.3.4.1 | **REDES DE DISTRIBUCIÓN DRENAJE PLUVIAL** | 1d | 2027-04-20 | 2027-04-20 |  | 5d |  | 1,024.75 | 09.04.01 | 1 día |
| 473 | 1.4.3.4.1.1 | TUBERIA PVC SAL 4" P/LLUVIAS | 1d | 2027-04-20 | 2027-04-20 | 407FF-5d | 5d |  | 1,024.75 | 09.04.01.01 | 1 día |

| ID | WBS | Task | Duration | Start | Finish | Predecessors | Total slack | Free slack | Cost | Text1 | Text2 |
| --- | --- | --- | --- | --- | --- | --- | --- | --- | --- | --- | --- |
| 474 | 1.4.3.4.2 | **ACCESORIOS DE DRENAJE PLUVIAL** | 1d | 2027-04-20 | 2027-04-20 |  | 5d |  | 1,000 | 09.04.02 | 1 día |
| 475 | 1.4.3.4.2.1 | ACCESORIOS DE DRENAJE PLUVIAL | 1d | 2027-04-20 | 2027-04-20 | 407FF-5d | 5d |  | 1,000 | 09.04.02.01 | 1 día |
| 476 | 1.4.3.5 | **DESAGÜE Y VENTILACIÓN** | 136d | 2026-11-13 | 2027-04-20 |  | 5d |  | 141,501.41 | 09.05 | 159 días |
| 477 | 1.4.3.5.1 | **SALIDAS DE DESAGÜE** | 13d | 2027-01-15 | 2027-01-30 |  | 74d |  | 31,034.04 | 09.05.01 | 16 días |
| 478 | 1.4.3.5.1.1 | SALIDA DE DESAGUE PVC SAL 2" | 3d | 2027-01-27 | 2027-01-30 | 435FF | 74d | 0d | 22,932.6 | 09.05.01.01 | 4 días |
| 479 | 1.4.3.5.1.2 | SALIDA DE DESAGUE PVC SAL 4" | 13d | 2027-01-15 | 2027-01-30 | 478FF | 74d |  | 8,101.44 | 09.05.01.02 | 16 días |
| 480 | 1.4.3.5.2 | **REDES DE DERIVACIÓN** | 67d | 2026-11-13 | 2027-01-30 |  | 74d |  | 102,812.91 | 09.05.02 | 79 días |
| 481 | 1.4.3.5.2.1 | TUBERIA PVC SAL PARA DESAGUE 4" | 56d | 2026-11-26 | 2027-01-30 | 478FF | 74d |  | 50,918.4 | 09.05.02.01 | 66 días |
| 482 | 1.4.3.5.2.2 | TUBERIA PVC SAL PARA VENTILACION 2" | 67d | 2026-11-13 | 2027-01-30 | 478FF | 74d |  | 51,894.51 | 09.05.02.02 | 79 días |
| 483 | 1.4.3.5.3 | **ACCESORIOS DE REDES COLECTORAS** | 11d | 2027-04-08 | 2027-04-20 |  | 5d |  | 6,109.49 | 09.05.03 | 13 días |
| 484 | 1.4.3.5.3.1 | SUMIDERO DE BRONCE 2" | 6d | 2027-04-14 | 2027-04-20 | 407FF-5d | 5d |  | 1,996.05 | 09.05.03.01 | 7 días |
| 485 | 1.4.3.5.3.2 | REGISTRO ROSCADO 4" | 11d | 2027-04-08 | 2027-04-20 | 407FF-5d | 5d |  | 4,113.44 | 09.05.03.02 | 13 días |
| 486 | 1.4.3.5.4 | **CÁMARAS DE INSPECCIÓN** | 1d | 2027-01-29 | 2027-01-30 |  | 74d |  | 1,544.97 | 09.05.04 | 2 días |
| 487 | 1.4.3.5.4.1 | CAJA DE REGISTRO DE 12"x24" DE CONCRETO INC/TAPA | 1d | 2027-01-29 | 2027-01-30 | 478FF | 74d |  | 1,544.97 | 09.05.04.01 | 2 días |
| 488 | 1.4.4 | **INSTALACIONES ELECTRICAS; TELECOMUNICACIONES Y ESPECIALES** | 122d | 2026-12-05 | 2027-04-25 |  | 0d |  | 270,027.5 | 10 | 142 días |
| 489 | 1.4.4.1 | **MOVIMIENTO DE TIERRAS** | 3d | 2026-12-05 | 2026-12-08 |  | 119d |  | 241.5 | 10.01 | 4 días |
| 490 | 1.4.4.1.1 | TRAZO, NIVELES Y REPLANTEO PRELIMINAR | 1d | 2026-12-05 | 2026-12-05 | 329 | 118d | 0d | 8.34 | 10.01.01 | 1 día |
| 491 | 1.4.4.1.2 | EXCAVACION DE ZANJA PARA RED DE TUBERIA | 1d | 2026-12-07 | 2026-12-07 | 490 | 118d | 0d | 64.37 | 10.01.02 | 1 día |
| 492 | 1.4.4.1.3 | RELLENO CON MATERIAL PROPIO COMPACTADO C/EQUIPO | 1d | 2026-12-08 | 2026-12-08 | 491 | 118d |  | 68.77 | 10.01.03 | 1 día |
| 493 | 1.4.4.1.4 | ACARREO MANUAL DE MATERIAL DE RELLENO | 1d | 2026-12-08 | 2026-12-08 | 491 | 118d |  | 100.02 | 10.01.04 | 1 día |
| 494 | 1.4.4.2 | **SALIDAS PARA ALUMBRADO, TOMACORRIENTES, FUERZA Y SEÑALES DÉBILES** | 80d | 2027-01-23 | 2027-04-25 |  | 0d |  | 118,620.66 | 10.02 | 93 días |
| 495 | 1.4.4.2.1 | **SALIDA** | 6d | 2027-01-23 | 2027-01-30 |  | 74d |  | 69,859.96 | 10.02.01 | 8 días |
| 496 | 1.4.4.2.1.1 | SALIDA DE ALUMBRADO EN TECHO | 6d | 2027-01-23 | 2027-01-30 | 497FF | 74d |  | 8,576.48 | 10.02.01.01 | 8 días |
| 497 | 1.4.4.2.1.2 | SALIDA DE ALUMBRADO EN PARED | 4d | 2027-01-26 | 2027-01-30 | 435FF | 74d | 0d | 5,953.92 | 10.02.01.02 | 5 días |
| 498 | 1.4.4.2.1.3 | SALIDA DE INTERRUPTOR SIMPLE | 4d | 2027-01-26 | 2027-01-30 | 497FF | 74d |  | 5,807.58 | 10.02.01.03 | 5 días |
| 499 | 1.4.4.2.1.4 | SALIDA DE INTERRUPTOR DOBLE | 2d | 2027-01-28 | 2027-01-30 | 497FF | 74d |  | 1,803.52 | 10.02.01.04 | 3 días |
| 500 | 1.4.4.2.1.5 | INTERRUPTOR DE CONMUTACION TRES VIAS (DOBLE) | 2d | 2027-01-28 | 2027-01-30 | 497FF | 74d |  | 3,731 | 10.02.01.05 | 3 días |
| 501 | 1.4.4.2.1.6 | SALIDA PARA TOMACORRIENTE BIPOLAR DOBLE + L.T. (TENSION COMERCIAL) | 5d | 2027-01-25 | 2027-01-30 | 497FF | 74d |  | 17,120.16 | 10.02.01.06 | 6 días |
| 502 | 1.4.4.2.1.7 | SALIDA PARA TOMACORRIENTE BIPOLAR SIMPLE + L.T. (LUZ DE EMERGENCIA) | 4d | 2027-01-26 | 2027-01-30 | 497FF | 74d |  | 16,571.79 | 10.02.01.07 | 5 días |
| 503 | 1.4.4.2.1.8 | SALIDA DE FUERZA ELECTRICA TRIFASICA | 1d | 2027-01-29 | 2027-01-30 | 497FF | 74d |  | 436.48 | 10.02.01.08 | 2 días |
| 504 | 1.4.4.2.1.9 | TOMA ELECTRICA TRIFASICA | 1d | 2027-01-29 | 2027-01-30 | 497FF | 74d |  | 33.64 | 10.02.01.09 | 2 días |
| 505 | 1.4.4.2.1.10 | CAJA OCTOGONAL PESADA | 2d | 2027-01-28 | 2027-01-30 | 497FF | 74d |  | 5,388.13 | 10.02.01.10 | 3 días |
| 506 | 1.4.4.2.1.11 | CAJA RECTANGULAR PESADA | 3d | 2027-01-27 | 2027-01-30 | 497FF | 74d |  | 1,529.6 | 10.02.01.11 | 4 días |
| 507 | 1.4.4.2.1.12 | CAJA CUADRADA DE F°G° DE PASE 100 DE 100X100 | 1d | 2027-01-29 | 2027-01-30 | 497FF | 74d |  | 232 | 10.02.01.12 | 2 días |
| 508 | 1.4.4.2.1.13 | CAJA CUADRADA DE F°G° DE PASE 150 DE 150X150 | 1d | 2027-01-29 | 2027-01-30 | 497FF | 74d |  | 568.35 | 10.02.01.13 | 2 días |
| 509 | 1.4.4.2.1.14 | CAJA CUADRADA DE F°G° DE PASE 200 DE 200X200 | 1d | 2027-01-29 | 2027-01-30 | 497FF | 74d |  | 113.67 | 10.02.01.14 | 2 días |
| 510 | 1.4.4.2.1.15 | SALIDA PARA CENTRAL TELEFONICA | 1d | 2027-01-29 | 2027-01-30 | 497FF | 74d |  | 19.8 | 10.02.01.15 | 2 días |
| 511 | 1.4.4.2.1.16 | SALIDA PARA CIRCUITO CERRADO DE TV | 1d | 2027-01-29 | 2027-01-30 | 497FF | 74d |  | 383.2 | 10.02.01.16 | 2 días |
| 512 | 1.4.4.2.1.17 | SALIDA PARA TV CABLE | 1d | 2027-01-29 | 2027-01-30 | 497FF | 74d |  | 1,458.52 | 10.02.01.17 | 2 días |
| 513 | 1.4.4.2.1.18 | SALIDA PARA CAMARA DE VIDEO | 1d | 2027-01-29 | 2027-01-30 | 497FF | 74d |  | 132.12 | 10.02.01.18 | 2 días |

| ID | WBS | Task | Duration | Start | Finish | Predecessors | Total slack | Cost | Text1 | Text2 |
| --- | --- | --- | --- | --- | --- | --- | --- | --- | --- | --- |
| 514 | 1.4.4.2.2 | **CANALIZACIONES, CONDUCTOS O TUBERÍAS** | 2d | 2027-01-28 | 2027-01-30 |  | 74d | 1,702.05 | 10.02.02 | 3 días |
| 515 | 1.4.4.2.2.1 | TUBERIA PVC-SAP (ELECTRICA) DE Ø 20 MM | 2d | 2027-01-28 | 2027-01-30 | 435FF | 74d | 1,151.62 | 10.02.02.01 | 3 días |
| 516 | 1.4.4.2.2.2 | TUBERIA PVC-SAP (ELECTRICA) DE Ø 25 MM | 1d | 2027-01-29 | 2027-01-30 | 435FF | 74d | 550.43 | 10.02.02.02 | 2 días |
| 517 | 1.4.4.2.3 | **CONDUCTORES Y CABLES DE ENERGÍA EN TUBERÍAS** | 2d | 2027-04-24 | 2027-04-25 |  | 0d | 43,060.46 | 10.02.03 | 2 días |
| 518 | 1.4.4.2.3.1 | ALIMENTADOR A TABLEROS GENERALES 3 - 1 X 16 MM2 + 1 X 16 MM2 (N) NYY | 1d | 2027-04-25 | 2027-04-25 | 408FF | 0d | 3,077.29 | 10.02.03.01 | 1 día |
| 519 | 1.4.4.2.3.2 | ALIMENTADOR PARA SALIDA DE FUERZA TRIFASICA CABLE DE 25 MM2 | 1d | 2027-04-25 | 2027-04-25 | 408FF | 0d | 3,652.8 | 10.02.03.02 | 1 día |
| 520 | 1.4.4.2.3.3 | ALIMENTADOR PARA SALIDA DE FUERZA TRIFASICA CABLE DE 10 MM2 | 1d | 2027-04-25 | 2027-04-25 | 408FF | 0d | 2,025.75 | 10.02.03.03 | 1 día |
| 521 | 1.4.4.2.3.4 | ALIMENTADOR A SUBTABLEROS DE DISTRIBUCION 2 - 1 x 10 mm2 | 1d | 2027-04-25 | 2027-04-25 | 408FF | 0d | 215.34 | 10.02.03.04 | 1 día |
| 522 | 1.4.4.2.3.5 | ALIMENTADOR A TABLEROS DE STANDS 2X10 MM2 NYY | 1d | 2027-04-25 | 2027-04-25 | 408FF | 0d | 900.95 | 10.02.03.05 | 1 día |
| 523 | 1.4.4.2.3.6 | CABLE DE COBRE DESNUDO 1 X 35 mm2 TEMPLE BLANDO P/TIERRA | 2d | 2027-04-24 | 2027-04-25 | 408FF | 0d | 33,188.33 | 10.02.03.06 | 2 días |
| 524 | 1.4.4.2.4 | **TABLERO DE DISTRIBUCIÓN, DISPOSITIVOS DE MANIOBRA Y PROTECCION** | 3d | 2027-04-23 | 2027-04-25 |  | 0d | 3,998.19 | 10.02.04 | 3 días |
| 525 | 1.4.4.2.4.1 | TABLERO GENERAL DE DISTRIBUCIÓN TG.D - 10G | 2d | 2027-04-24 | 2027-04-25 | 408FF | 0d | 2,028.21 | 10.02.04.01 | 2 días |
| 526 | 1.4.4.2.4.2 | TABLERO ELECTRICO DE STANDS GENERALES | 3d | 2027-04-23 | 2027-04-25 | 408FF | 0d | 1,969.98 | 10.02.04.02 | 3 días |
| 527 | 1.4.4.3 | **ARTEFACTOS DE ALUMBRADO** | 10d | 2027-04-15 | 2027-04-25 |  | 0d | 30,133.29 | 10.03 | 11 días |
| 528 | 1.4.4.3.1 | ARTEFACTO FLUORESCENTE RAS 2X36 W, REJILLA | 1d | 2027-04-25 | 2027-04-25 | 408FF | 0d | 187.08 | 10.03.01 | 1 día |
| 529 | 1.4.4.3.2 | ARTEFACTO FLUORESCENTE HERMETICO 2X36 W | 3d | 2027-04-23 | 2027-04-25 | 408FF | 0d | 7,055.51 | 10.03.02 | 3 días |
| 530 | 1.4.4.3.3 | ARTEFACTO BRAQUETE MODELO RSP TC-DEL 2X18 W, EXTERIOR | 5d | 2027-04-21 | 2027-04-25 | 408FF | 0d | 15,101.82 | 10.03.03 | 5 días |
| 531 | 1.4.4.3.4 | INSTALACION DE SOKET INC. FOCO AHORRADOR TIPO GLOBO 1X18 W | 10d | 2027-04-15 | 2027-04-25 | 408FF | 0d | 7,788.88 | 10.03.04 | 11 días |
| 532 | 1.4.4.4 | **INSTALACIÓN DEL SISTEMA DE PUESTA A TIERRA** | 1d | 2027-04-25 | 2027-04-25 |  | 0d | 1,738.8 | 10.04 | 1 día |
| 533 | 1.4.4.4.1 | POZO DE PUESTA A TIERRA <= 15 OHMS | 1d | 2027-04-25 | 2027-04-25 | 408FF | 0d | 1,738.8 | 10.04.01 | 1 día |
| 534 | 1.4.4.5 | **OTROS** | 3d | 2027-04-23 | 2027-04-25 |  | 0d | 5,458.24 | 10.05 | 3 días |
| 535 | 1.4.4.5.1 | **PRUEBA Y ENERGIZACION** | 3d | 2027-04-23 | 2027-04-25 |  | 0d | 5,458.24 | 10.05.01 | 3 días |
| 536 | 1.4.4.5.1.1 | PRUEBAS ELECTRICAS | 3d | 2027-04-23 | 2027-04-25 | 408FF | 0d | 5,201.97 | 10.05.01.01 | 3 días |
| 537 | 1.4.4.5.1.2 | INSTALACION DE MEDIDOR DE ENERGIA ELECTRICA | 1d | 2027-04-25 | 2027-04-25 | 408FF | 0d | 256.27 | 10.05.01.02 | 1 día |

| ID | WBS | Task | Duration | Start | Finish | Predecessors | Total slack | Free slack | Cost | Text1 | Text2 |
| --- | --- | --- | --- | --- | --- | --- | --- | --- | --- | --- | --- |
| 538 | 1.4.4.6 | **INSTALACION DE SISTEMAS DE TELECOMUNICACIONES Y ESPECIALES** | 1d | 2027-04-25 | 2027-04-25 |  | 0d |  | 7,234 | 10.06 | 1 día |
| 539 | 1.4.4.6.1 | **INSTALACIONES DE AUDIO Y SONIDO** | 1d | 2027-04-25 | 2027-04-25 |  | 0d |  | 7,234 | 10.06.01 | 1 día |
| 540 | 1.4.4.6.1.1 | SUMINISTRO E INSTALACION DE CABLE DE AUDIO | 1d | 2027-04-25 | 2027-04-25 | 408FF | 0d |  | 1,516.8 | 10.06.01.01 | 1 día |
| 541 | 1.4.4.6.1.2 | INSTALACION DE PARLANTES DE SONIDO | 1d | 2027-04-25 | 2027-04-25 | 408FF | 0d |  | 444.96 | 10.06.01.02 | 1 día |
| 542 | 1.4.4.6.1.3 | INSTALACION DE CONSOLA EQUIPO DE SONIDO P/PARLANTE | 1d | 2027-04-25 | 2027-04-25 | 408FF | 0d |  | 5,272.24 | 10.06.01.03 | 1 día |
| 543 | 1.4.4.7 | **INSTALACION DE SISTEMA CONTRAINCENDIOS** | 7d | 2027-04-19 | 2027-04-25 |  | 0d |  | 106,601.01 | 10.07 | 7 días |
| 544 | 1.4.4.7.1 | INSTALACION DE CABLE CONTRA INCENDIO | 1d | 2027-04-25 | 2027-04-25 | 408FF | 0d |  | 11.8 | 10.07.01 | 1 día |
| 545 | 1.4.4.7.2 | SUMINISTRO INSTALACION DE DETECTOR DE HUMO | 4d | 2027-04-22 | 2027-04-25 | 408FF | 0d |  | 18,613.65 | 10.07.02 | 4 días |
| 546 | 1.4.4.7.3 | SUMINISTRO INSTALACION DE DETECTOR DE TEMPERATURA | 3d | 2027-04-23 | 2027-04-25 | 408FF | 0d |  | 19,454 | 10.07.03 | 3 días |
| 547 | 1.4.4.7.4 | SUMINISTRO E INSTALACION LUZ ESTROBOSCOPICA C/INCENDIO | 7d | 2027-04-19 | 2027-04-25 | 408FF | 0d |  | 38,395.98 | 10.07.04 | 7 días |
| 548 | 1.4.4.7.5 | SUMINISTRO E INSTALACION ESTACION MANUAL C/INCENDIO | 2d | 2027-04-24 | 2027-04-25 | 408FF | 0d |  | 7,313.52 | 10.07.05 | 2 días |
| 549 | 1.4.4.7.6 | SUMINISTRO E INSTALACION DE CENTRAL DE ALARMA CONTRAINCENDIO | 5d | 2027-04-21 | 2027-04-25 | 408FF | 0d |  | 22,253.22 | 10.07.06 | 5 días |
| 550 | 1.4.4.7.7 | CONFIGURACION DE SISTEMAS DE ALARMAS CONTRA INCENDIOS SENSOR INTELIGENTE | 1d | 2027-04-25 | 2027-04-25 | 408FF | 0d |  | 558.84 | 10.07.07 | 1 día |
| 551 | 1.4.5 | **EQUIPAMIENTO** | 12d | 2027-04-13 | 2027-04-25 |  | 0d |  | 78,000 | 11 | 13 días |
| 552 | 1.4.5.1 | CAMARAS DE CONGELAMIENTO | 12d | 2027-04-13 | 2027-04-25 | 408FF | 0d |  | 60,000 | 11.01 | 13 días |
| 553 | 1.4.5.2 | EQUIPAMIENTO DE PATIO DE COMIDAS | 1d | 2027-04-25 | 2027-04-25 | 408FF | 0d |  | 18,000 | 11.02 | 1 día |
| 554 | 1.5 | **AREAS DE ESPARCIMIENTO** | 227d | 2026-06-01 | 2027-02-19 |  | 56d |  | 439,424.28 |  | 264 días |
| 555 | 1.5.1 | **VEREDAS INTERNAS** | 204d | 2026-06-01 | 2027-01-23 |  | 79d |  | 55,650.45 | 12 | 237 días |
| 556 | 1.5.1.1 | **LOSA CIRCULAR DE PLAZA CENTRAL** | 201d | 2026-06-02 | 2027-01-21 |  | 81d |  | 10,296.24 | 12.01 | 234 días |
| 557 | 1.5.1.1.1 | **ESTRUCTURA** | 201d | 2026-06-02 | 2027-01-21 |  | 81d |  | 7,003.32 | 12.01.01 | 234 días |
| 558 | 1.5.1.1.1.1 | **TRABAJOS PRELIMINARES** | 1d | 2026-06-04 | 2026-06-04 |  | 279d |  | 128.04 | 12.01.01.01 | 1 día |
| 559 | 1.5.1.1.1.1.1 | LIMPIEZA INICIAL DE OBRA | 1d | 2026-06-04 | 2026-06-04 | 564FF | 278d |  | 45.57 | 12.01.01.01.01 | 1 día |
| 560 | 1.5.1.1.1.1.2 | TRAZO Y REPLANTEO PRELIMINAR | 1d | 2026-06-04 | 2026-06-04 | 564FF | 278d |  | 82.47 | 12.01.01.01.02 | 1 día |
| 561 | 1.5.1.1.1.2 | **MOVIMIENTO DE TIERRAS** | 5d | 2026-06-02 | 2026-06-06 |  | 266d |  | 2,766.64 | 12.01.01.02 | 5 días |
| 562 | 1.5.1.1.1.2.1 | NIVELACION Y COMPACTACION DE TERRENO | 1d | 2026-06-05 | 2026-06-05 | 563 | 276d | 0d | 496.98 | 12.01.01.02.01 | 1 día |
| 563 | 1.5.1.1.1.2.2 | EXCAVACION PLAZA PRINCIPAL | 1d | 2026-06-04 | 2026-06-04 | 301 | 262d | 0d | 491.07 | 12.01.01.02.02 | 1 día |
| 564 | 1.5.1.1.1.2.3 | ELIMINACION MATERIAL EXCEDENTE C/MAQUINA | 1d | 2026-06-04 | 2026-06-04 | 563FF | 278d | 0d | 523.48 | 12.01.01.02.03 | 1 día |
| 565 | 1.5.1.1.1.2.4 | ACARREO MANUAL DE MATERIAL EXCEDENTE | 3d | 2026-06-02 | 2026-06-04 | 563FF | 278d |  | 473.11 | 12.01.01.02.04 | 3 días |
| 566 | 1.5.1.1.1.2.5 | BASE GRANULAR COMPACTADA E=0.20 M | 1d | 2026-06-06 | 2026-06-06 | 562 | 276d |  | 782 | 12.01.01.02.05 | 1 día |

| ID | WBS | Task | Duration | Start | Finish | Predecessors | Total slack | Free slack | Cost | Text1 | Text2 |
| --- | --- | --- | --- | --- | --- | --- | --- | --- | --- | --- | --- |
| 567 | 1.5.1.1.1.3 | **OBRAS DE CONCRETO SIMPLE** | 4d | 2027-01-18 | 2027-01-21 |  | 81d |  | 4,108.64 | 12.01.01.03 | 4 días |
| 568 | 1.5.1.1.1.3.1 | ENCOFRADO Y DESENCOFRADO | 1d | 2027-01-18 | 2027-01-18 | 348 | 81d | 0d | 1,180.4 | 12.01.01.03.01 | 1 día |
| 569 | 1.5.1.1.1.3.2 | CONCRETO F'C=210 KG/CM2, PARA LOSA | 1d | 2027-01-19 | 2027-01-19 | 568 | 81d | 0d | 2,784.23 | 12.01.01.03.02 | 1 día |
| 570 | 1.5.1.1.1.3.3 | CURADO DE LOSA CON ADITIVO | 1d | 2027-01-20 | 2027-01-20 | 569 | 81d | 0d | 60.4 | 12.01.01.03.03 | 1 día |
| 571 | 1.5.1.1.1.3.4 | JUNTAS ASFALTICAS | 1d | 2027-01-21 | 2027-01-21 | 570 | 81d |  | 83.61 | 12.01.01.03.04 | 1 día |
| 572 | 1.5.1.1.2 | **ARQUITECTURA** | 1d | 2027-01-20 | 2027-01-20 |  | 82d |  | 3,292.92 | 12.01.02 | 1 día |
| 573 | 1.5.1.1.2.1 | **PISOS Y PAVIMENTOS** | 1d | 2027-01-20 | 2027-01-20 |  | 82d |  | 3,292.92 | 12.01.02.01 | 1 día |
| 574 | 1.5.1.1.2.1.1 | PISOS DE PIEDRA LAJA PLAZA PRINCIPAL | 1d | 2027-01-20 | 2027-01-20 | 569 | 82d |  | 3,292.92 | 12.01.02.01.01 | 1 día |
| 575 | 1.5.1.2 | **AREA DE STAR** | 199d | 2026-06-04 | 2027-01-21 |  | 81d |  | 11,166.36 | 12.02 | 232 días |
| 576 | 1.5.1.2.1 | **LOSA DE ESTAR** | 199d | 2026-06-04 | 2027-01-21 |  | 81d |  | 11,166.36 | 12.02.01 | 232 días |
| 577 | 1.5.1.2.1.1 | **ESTRUCTURA** | 199d | 2026-06-04 | 2027-01-21 |  | 81d |  | 8,071.91 | 12.02.01.01 | 232 días |
| 578 | 1.5.1.2.1.1.1 | **TRABAJOS PRELIMINARES** | 1d | 2026-06-06 | 2026-06-06 |  | 277d |  | 120.33 | 12.02.01.01.01 | 1 día |
| 579 | 1.5.1.2.1.1.1.1 | LIMPIEZA INICIAL DE OBRA | 1d | 2026-06-06 | 2026-06-06 | 584FF | 277d |  | 42.83 | 12.02.01.01.01.01 | 1 día |
| 580 | 1.5.1.2.1.1.1.2 | TRAZO Y REPLANTEO PRELIMINAR | 1d | 2026-06-06 | 2026-06-06 | 584FF | 277d |  | 77.5 | 12.02.01.01.01.02 | 1 día |
| 581 | 1.5.1.2.1.1.2 | **MOVIMIENTOS DE TIERRA** | 4d | 2026-06-04 | 2026-06-08 |  | 264d |  | 2,738.59 | 12.02.01.01.02 | 5 días |
| 582 | 1.5.1.2.1.1.2.1 | NIVELACION Y COMPACTACION DE TERRENO | 1d | 2026-06-05 | 2026-06-05 | 583 | 277d |  | 467.02 | 12.02.01.01.02.01 | 1 día |
| 583 | 1.5.1.2.1.1.2.2 | EXCAVACION MANUAL EN TERRENO NORMAL H>1M | 1d | 2026-06-04 | 2026-06-04 | 563FF | 262d | 0d | 600.15 | 12.02.01.01.02.02 | 1 día |
| 584 | 1.5.1.2.1.1.2.3 | ACARREO MANUAL DE MATERIAL EXCEDENTE | 3d | 2026-06-04 | 2026-06-06 | 583SS | 275d | 0d | 444.61 | 12.02.01.01.02.03 | 3 días |
| 585 | 1.5.1.2.1.1.2.4 | BASE GRANULAR COMPACTADA E=0.20 M | 1d | 2026-06-06 | 2026-06-06 | 582 | 277d |  | 734.86 | 12.02.01.01.02.04 | 1 día |
| 586 | 1.5.1.2.1.1.2.5 | ELIMINACION MATERIAL EXCEDENTE C/MAQUINA | 1d | 2026-06-08 | 2026-06-08 | 584 | 276d |  | 491.95 | 12.02.01.01.02.05 | 1 día |
| 587 | 1.5.1.2.1.1.3 | **OBRAS DE CONCRETO SIMPLE** | 4d | 2027-01-18 | 2027-01-21 |  | 81d |  | 5,212.99 | 12.02.01.01.03 | 4 días |
| 588 | 1.5.1.2.1.1.3.1 | ENCOFRADO Y DESENCOFRADO | 1d | 2027-01-18 | 2027-01-18 | 348 | 81d | 0d | 2,113.43 | 12.02.01.01.03.01 | 1 día |
| 589 | 1.5.1.2.1.1.3.2 | CONCRETO F'C=210 KG/CM2, PARA LOSA | 1d | 2027-01-19 | 2027-01-19 | 588 | 81d | 0d | 2,615.03 | 12.02.01.01.03.02 | 1 día |
| 590 | 1.5.1.2.1.1.3.3 | CURADO DE LOSA CON ADITIVO | 1d | 2027-01-20 | 2027-01-20 | 589 | 81d | 0d | 56.76 | 12.02.01.01.03.03 | 1 día |
| 591 | 1.5.1.2.1.1.3.4 | JUNTAS ASFALTICAS | 1d | 2027-01-21 | 2027-01-21 | 590 | 81d |  | 427.77 | 12.02.01.01.03.04 | 1 día |

| ID | WBS | Task | Duration | Start | Finish | Predecessors | Total slack | Free slack | Cost | Text1 | Text2 |
| --- | --- | --- | --- | --- | --- | --- | --- | --- | --- | --- | --- |
| 592 | 1.5.1.2.1.2 | **ARQUITECTURA** | 1d | 2027-01-20 | 2027-01-20 |  | 82d |  | 3,094.45 | 12.02.01.02 | 1 día |
| 593 | 1.5.1.2.1.2.1 | **PISOS Y PAVIMENTOS** | 1d | 2027-01-20 | 2027-01-20 |  | 82d |  | 3,094.45 | 12.02.01.02.01 | 1 día |
| 594 | 1.5.1.2.1.2.1.1 | PISOS DE PIEDRA LAJA ZONA STAR | 1d | 2027-01-20 | 2027-01-20 | 589 | 82d |  | 3,094.45 | 12.02.01.02.01.01 | 1 día |
| 595 | 1.5.1.3 | **INGRESOS** | 204d | 2026-06-01 | 2027-01-23 |  | 79d |  | 34,187.85 | 12.03 | 237 días |
| 596 | 1.5.1.3.1 | **LOSA CIRCULAR DE PLAZA CENTRAL** | 204d | 2026-06-01 | 2027-01-23 |  | 79d |  | 34,187.85 | 12.03.01 | 237 días |
| 597 | 1.5.1.3.1.1 | **ESTRUCTURA** | 203d | 2026-06-01 | 2027-01-22 |  | 80d |  | 23,334.06 | 12.03.01.01 | 236 días |
| 598 | 1.5.1.3.1.1.1 | **TRABAJOS PRELIMINARES** | 1d | 2026-06-01 | 2026-06-02 |  | 282d |  | 422.04 | 12.03.01.01.01 | 2 días |
| 599 | 1.5.1.3.1.1.1.1 | LIMPIEZA INICIAL DE OBRA | 1d | 2026-06-01 | 2026-06-02 | 602SF | 282d |  | 150.22 | 12.03.01.01.01.01 | 2 días |
| 600 | 1.5.1.3.1.1.1.2 | TRAZO Y REPLANTEO PRELIMINAR | 1d | 2026-06-01 | 2026-06-02 | 602SF | 281d |  | 271.82 | 12.03.01.01.01.02 | 2 días |
| 601 | 1.5.1.3.1.1.2 | **MOVIMIENTO DE TIERRAS** | 18d | 2026-06-02 | 2026-06-22 |  | 264d |  | 9,604.51 | 12.03.01.01.02 | 21 días |
| 602 | 1.5.1.3.1.1.2.1 | EXCAVACION MANUAL EN TERRENO NORMAL H>1M | 3d | 2026-06-02 | 2026-06-04 | 583FF | 262d | 0d | 2,104.59 | 12.03.01.01.02.01 | 3 días |
| 603 | 1.5.1.3.1.1.2.2 | NIVELACION Y COMPACTACION DE TERRENO | 4d | 2026-06-16 | 2026-06-19 | 604FS+2d | 263d | 0d | 1,638.08 | 12.03.01.01.02.02 | 4 días |
| 604 | 1.5.1.3.1.1.2.3 | ACARREO MANUAL DE MATERIAL EXCEDENTE | 7d | 2026-06-05 | 2026-06-12 | 602 | 263d | 0d | 1,559.15 | 12.03.01.01.02.03 | 8 días |
| 605 | 1.5.1.3.1.1.2.4 | BASE GRANULAR COMPACTADA E=0.20 M | 2d | 2026-06-20 | 2026-06-22 | 603 | 263d |  | 2,577.54 | 12.03.01.01.02.04 | 3 días |
| 606 | 1.5.1.3.1.1.2.5 | ELIMINACION MATERIAL EXCEDENTE C/MAQUINA | 1d | 2026-06-20 | 2026-06-20 | 603 | 264d |  | 1,725.15 | 12.03.01.01.02.05 | 1 día |
| 607 | 1.5.1.3.1.1.3 | **OBRAS DE CONCRETO SIMPLE** | 5d | 2027-01-18 | 2027-01-22 |  | 79d |  | 13,307.51 | 12.03.01.01.03 | 5 días |
| 608 | 1.5.1.3.1.1.3.1 | ENCOFRADO Y DESENCOFRADO | 2d | 2027-01-18 | 2027-01-19 | 348 | 79d | 0d | 3,277.23 | 12.03.01.01.03.01 | 2 días |
| 609 | 1.5.1.3.1.1.3.2 | CONCRETO F'C=210 KG/CM2 | 1d | 2027-01-20 | 2027-01-20 | 608 | 79d | 0d | 9,167.97 | 12.03.01.01.03.02 | 1 día |
| 610 | 1.5.1.3.1.1.3.3 | CURADO DE CONCRETO | 1d | 2027-01-21 | 2027-01-21 | 609 | 80d | 0d | 199.1 | 12.03.01.01.03.03 | 1 día |
| 611 | 1.5.1.3.1.1.3.4 | JUNTAS ASFALTICAS | 1d | 2027-01-22 | 2027-01-22 | 610 | 80d |  | 663.21 | 12.03.01.01.03.04 | 1 día |
| 612 | 1.5.1.3.1.2 | **ARQUITECTURA** | 3d | 2027-01-21 | 2027-01-23 |  | 79d |  | 10,853.79 | 12.03.01.02 | 3 días |
| 613 | 1.5.1.3.1.2.1 | **PISOS Y PAVIMENTOS** | 3d | 2027-01-21 | 2027-01-23 |  | 79d |  | 10,853.79 | 12.03.01.02.01 | 3 días |
| 614 | 1.5.1.3.1.2.1.1 | PISOS DE PIEDRA LAJA EN INGRESO A LA PLAZA | 3d | 2027-01-21 | 2027-01-23 | 609 | 79d |  | 10,853.79 | 12.03.01.02.01.01 | 3 días |
| 615 | 1.5.2 | **SARDINELES** | 215d | 2026-06-03 | 2027-02-08 |  | 66d |  | 38,267.32 | 13 | 251 días |
| 616 | 1.5.2.1 | **ESTRUCTURA** | 204d | 2026-06-03 | 2027-01-26 |  | 77d |  | 18,269.7 | 13.01 | 238 días |
| 617 | 1.5.2.1.1 | **TRABAJOS PRELIMINARES** | 1d | 2026-06-03 | 2026-06-04 |  | 280d |  | 50.05 | 13.01.01 | 2 días |
| 618 | 1.5.2.1.1.1 | TRAZO Y REPLANTEO PRELIMINAR | 1d | 2026-06-03 | 2026-06-04 | 620SF | 280d |  | 50.05 | 13.01.01.01 | 2 días |

| ID | WBS | Task | Duration | Start | Finish | Predecessors | Total slack | Free slack | Cost | Text1 | Text2 |
| --- | --- | --- | --- | --- | --- | --- | --- | --- | --- | --- | --- |
| 619 | 1.5.2.1.2 | **MOVIMIENTO DE TIERRAS** | 4d | 2026-06-04 | 2026-06-08 |  | 268d |  | 1,052.49 | 13.01.02 | 5 días |
| 620 | 1.5.2.1.2.1 | EXCAVACION MANUAL EN TERRENO NORMAL H>1M | 1d | 2026-06-04 | 2026-06-04 | 602FF | 267d | 0d | 347.6 | 13.01.02.01 | 1 día |
| 621 | 1.5.2.1.2.2 | ACARREO MANUAL DE MATERIAL EXCEDENTE | 2d | 2026-06-05 | 2026-06-06 | 620 | 276d | 0d | 334.63 | 13.01.02.02 | 2 días |
| 622 | 1.5.2.1.2.3 | ELIMINACION MATERIAL EXCEDENTE C/MAQUINA | 1d | 2026-06-08 | 2026-06-08 | 621 | 276d |  | 370.26 | 13.01.02.03 | 1 día |
| 623 | 1.5.2.1.3 | **OBRAS DE CONCRETO SIMPLE** | 8d | 2027-01-18 | 2027-01-26 |  | 66d |  | 17,167.16 | 13.01.03 | 9 días |
| 624 | 1.5.2.1.3.1 | CONCRETO C:H 1:10 E=4" - SOLADO | 1d | 2027-01-18 | 2027-01-18 | 348 | 66d | 0d | 689.89 | 13.01.03.01 | 1 día |
| 625 | 1.5.2.1.3.2 | CONCRETO CICLOPEO C:H PROP 1:8 + 30% PM | 1d | 2027-01-25 | 2027-01-25 | 626 | 78d |  | 2,628.4 | 13.01.03.02 | 1 día |
| 626 | 1.5.2.1.3.3 | ENCOFRADO Y DESENCOFRADO | 5d | 2027-01-19 | 2027-01-23 | 624 | 66d | 0d | 9,715.49 | 13.01.03.03 | 5 días |
| 627 | 1.5.2.1.3.4 | CONCRETO F'C=210 KG/CM2 | 1d | 2027-01-25 | 2027-01-25 | 626 | 66d | 0d | 3,937.92 | 13.01.03.04 | 1 día |
| 628 | 1.5.2.1.3.5 | CURADO DE CONCRETO | 1d | 2027-01-26 | 2027-01-26 | 627 | 66d | 0d | 195.46 | 13.01.03.05 | 1 día |
| 629 | 1.5.2.2 | **ARQUITECTURA** | 11d | 2027-01-27 | 2027-02-08 |  | 66d |  | 19,997.62 | 13.02 | 13 días |
| 630 | 1.5.2.2.1 | **REVOQUES Y REVESTIMIENTOS** | 5d | 2027-01-27 | 2027-02-01 |  | 66d |  | 2,188.49 | 13.02.01 | 6 días |
| 631 | 1.5.2.2.1.1 | TARRAJEO DE MUROS EXTERIORES | 5d | 2027-01-27 | 2027-02-01 | 628 | 66d | 0d | 2,188.49 | 13.02.01.01 | 6 días |
| 632 | 1.5.2.2.2 | **PINTURA** | 3d | 2027-02-05 | 2027-02-08 |  | 66d |  | 1,777.58 | 13.02.02 | 4 días |
| 633 | 1.5.2.2.2.1 | PINTURA LÁTEX EN MUROS | 3d | 2027-02-05 | 2027-02-08 | 631FS+3d | 66d |  | 1,777.58 | 13.02.02.01 | 4 días |
| 634 | 1.5.2.2.3 | **CARPINTERIA METALICA** | 6d | 2027-01-27 | 2027-02-02 |  | 71d |  | 16,031.55 | 13.02.03 | 7 días |
| 635 | 1.5.2.2.3.1 | CERCO METALICO DE AREAS VERDES | 6d | 2027-01-27 | 2027-02-02 | 631SS | 71d |  | 16,031.55 | 13.02.03.01 | 7 días |
| 636 | 1.5.3 | **JARDINERAS** | 226d | 2026-06-02 | 2027-02-19 |  | 56d |  | 193,918.19 | 14 | 263 días |
| 637 | 1.5.3.1 | **ESTRUCTURA** | 211d | 2026-06-02 | 2027-02-02 |  | 71d |  | 117,869.75 | 14.01 | 246 días |
| 638 | 1.5.3.1.1 | **TRABAJOS PRELIMINARES** | 1d | 2026-06-02 | 2026-06-03 |  | 281d |  | 105.81 | 14.01.01 | 2 días |
| 639 | 1.5.3.1.1.1 | TRAZO Y REPLANTEO PRELIMINAR | 1d | 2026-06-02 | 2026-06-03 | 641SF | 280d |  | 105.81 | 14.01.01.01 | 2 días |
| 640 | 1.5.3.1.2 | **MOVIMIENTO DE TIERRAS** | 9d | 2026-06-03 | 2026-06-12 |  | 268d |  | 3,399.01 | 14.01.02 | 10 días |
| 641 | 1.5.3.1.2.1 | EXCAVACION MANUAL EN TERRENO NORMAL H>1M | 2d | 2026-06-03 | 2026-06-04 | 620FF | 267d | 0d | 1,050.03 | 14.01.02.01 | 2 días |
| 642 | 1.5.3.1.2.2 | ACARREO MANUAL DE MATERIAL EXCEDENTE | 5d | 2026-06-05 | 2026-06-10 | 641 | 272d | 0d | 1,011.26 | 14.01.02.02 | 6 días |
| 643 | 1.5.3.1.2.3 | ELIMINACION MATERIAL EXCEDENTE C/MAQUINA | 1d | 2026-06-12 | 2026-06-12 | 644 | 272d |  | 1,118.94 | 14.01.02.03 | 1 día |
| 644 | 1.5.3.1.2.4 | RELLENO MANUAL CON MATERIAL PROPIO | 1d | 2026-06-11 | 2026-06-11 | 642 | 272d | 0d | 218.78 | 14.01.02.04 | 1 día |

| ID | WBS | Task | Duration | Start | Finish | Predecessors | Total slack | Free slack | Cost | Text1 | Text2 |
| --- | --- | --- | --- | --- | --- | --- | --- | --- | --- | --- | --- |
| 645 | 1.5.3.1.3 | **OBRAS DE CONCRETO SIMPLE** | 14d | 2027-01-18 | 2027-02-02 |  | 56d |  | 114,364.93 | 14.01.03 | 16 días |
| 646 | 1.5.3.1.3.1 | ENCOFRADO Y DESENCOFRADO | 8d | 2027-01-18 | 2027-01-26 | 348 | 56d | 0d | 77,044.9 | 14.01.03.01 | 9 días |
| 647 | 1.5.3.1.3.2 | CONCRETO F'C=210 KG/CM2 | 4d | 2027-01-27 | 2027-01-30 | 646 | 56d | 0d | 35,692.53 | 14.01.03.02 | 4 días |
| 648 | 1.5.3.1.3.3 | CURADO DE CONCRETO | 2d | 2027-02-01 | 2027-02-02 | 647 | 71d |  | 1,627.5 | 14.01.03.03 | 2 días |
| 649 | 1.5.3.2 | **ARQUITECTURA** | 17d | 2027-02-01 | 2027-02-19 |  | 56d |  | 76,048.44 | 14.02 | 19 días |
| 650 | 1.5.3.2.1 | **REVOQUES Y REVESTIMIENTOS** | 17d | 2027-02-01 | 2027-02-19 |  | 56d |  | 76,048.44 | 14.02.01 | 19 días |
| 651 | 1.5.3.2.1.1 | ENCHAPE DE PIEDRA JARDINERAS | 17d | 2027-02-01 | 2027-02-19 | 647 | 56d |  | 76,048.44 | 14.02.01.01 | 19 días |
| 652 | 1.5.4 | **PORTALES** | 217d | 2026-06-02 | 2027-02-09 |  | 65d |  | 36,015.83 | 15 | 253 días |
| 653 | 1.5.4.1 | **ESTRUCTURA** | 208d | 2026-06-02 | 2027-01-29 |  | 74d |  | 25,862.87 | 15.01 | 242 días |
| 654 | 1.5.4.1.1 | **TRABAJOS PRELIMINARES** | 1d | 2026-06-02 | 2026-06-03 |  | 281d |  | 41.04 | 15.01.01 | 2 días |
| 655 | 1.5.4.1.1.1 | TRAZO Y REPLANTEO PRELIMINAR | 1d | 2026-06-02 | 2026-06-03 | 657SF | 280d |  | 41.04 | 15.01.01.01 | 2 días |
| 656 | 1.5.4.1.2 | **MOVIMIENTOS DE TIERRA** | 9d | 2026-06-03 | 2026-06-12 |  | 268d |  | 3,333.51 | 15.01.02 | 10 días |
| 657 | 1.5.4.1.2.1 | EXCAVACION MANUAL EN TERRENO NORMAL H>1M | 2d | 2026-06-03 | 2026-06-04 | 641FF | 267d | 0d | 1,222.02 | 15.01.02.01 | 2 días |
| 658 | 1.5.4.1.2.2 | PERFILADO, NIVELACIÓN Y COMPACTADO DE ZANJA | 1d | 2026-06-05 | 2026-06-05 | 657 | 272d | 0d | 204.48 | 15.01.02.02 | 1 día |
| 659 | 1.5.4.1.2.3 | ACARREO MANUAL DE MATERIAL EXCEDENTE | 5d | 2026-06-06 | 2026-06-11 | 658 | 272d | 0d | 905.31 | 15.01.02.03 | 6 días |
| 660 | 1.5.4.1.2.4 | ELIMINACION MATERIAL EXCEDENTE C/MAQUINA | 1d | 2026-06-12 | 2026-06-12 | 659 | 272d |  | 1,001.7 | 15.01.02.04 | 1 día |
| 661 | 1.5.4.1.3 | **OBRAS DE CONCRETO SIMPLE** | 1d | 2027-01-18 | 2027-01-18 |  | 65d |  | 565.74 | 15.01.03 | 1 día |
| 662 | 1.5.4.1.3.1 | CONCRETO C:H 1:10 E=4" - SOLADO | 1d | 2027-01-18 | 2027-01-18 | 348 | 65d | 0d | 565.74 | 15.01.03.01 | 1 día |
| 663 | 1.5.4.1.4 | **OBRAS DE CONCRETO ARMADO** | 10d | 2027-01-19 | 2027-01-29 |  | 65d |  | 21,922.58 | 15.01.04 | 11 días |
| 664 | 1.5.4.1.4.1 | **ZAPATA** | 5d | 2027-01-19 | 2027-01-23 |  | 65d |  | 7,412.21 | 15.01.04.01 | 5 días |
| 665 | 1.5.4.1.4.1.1 | ACERO F'Y=4200 KG/CM2 GRADO 60 | 2d | 2027-01-19 | 2027-01-20 | 662 | 65d | 0d | 1,844.45 | 15.01.04.01.01 | 2 días |
| 666 | 1.5.4.1.4.1.2 | CONCRETO F'C=210 KG/CM2 | 2d | 2027-01-21 | 2027-01-22 | 665 | 65d | 0d | 5,537.7 | 15.01.04.01.02 | 2 días |
| 667 | 1.5.4.1.4.1.3 | CURADO DE CONCRETO | 1d | 2027-01-23 | 2027-01-23 | 666 | 79d |  | 30.06 | 15.01.04.01.03 | 1 día |
| 668 | 1.5.4.1.4.2 | **COLUMNAS** | 6d | 2027-01-23 | 2027-01-29 |  | 65d |  | 14,510.37 | 15.01.04.02 | 7 días |
| 669 | 1.5.4.1.4.2.1 | ACERO F'Y=4200 KG/CM2 GRADO 60 | 4d | 2027-01-23 | 2027-01-27 | 666 | 76d |  | 1,639.28 | 15.01.04.02.01 | 5 días |
| 670 | 1.5.4.1.4.2.2 | ENCOFRADO Y DESENCOFRADO | 4d | 2027-01-23 | 2027-01-27 | 666 | 65d | 0d | 7,968.96 | 15.01.04.02.02 | 5 días |
| 671 | 1.5.4.1.4.2.3 | CONCRETO F'C=210 KG/CM2 | 1d | 2027-01-28 | 2027-01-28 | 670 | 65d | 0d | 4,741.81 | 15.01.04.02.03 | 1 día |
| 672 | 1.5.4.1.4.2.4 | CURADO DE CONCRETO | 1d | 2027-01-29 | 2027-01-29 | 671 | 74d |  | 160.32 | 15.01.04.02.04 | 1 día |

| ID | WBS | Task | Duration | Start | Finish | Predecessors | Total slack | Free slack | Cost | Text1 | Text2 |
| --- | --- | --- | --- | --- | --- | --- | --- | --- | --- | --- | --- |
| 673 | 1.5.4.2 | **ARQUITECTURA** | 10d | 2027-01-29 | 2027-02-09 |  | 65d |  | 10,152.96 | 15.02 | 12 días |
| 674 | 1.5.4.2.1 | **REVOQUES Y REVESTIMIENTOS** | 10d | 2027-01-29 | 2027-02-09 |  | 65d |  | 10,152.96 | 15.02.01 | 12 días |
| 675 | 1.5.4.2.1.1 | ENCHAPE CON SILLAR BLANCO | 10d | 2027-01-29 | 2027-02-09 | 671 | 65d |  | 10,152.96 | 15.02.01.01 | 12 días |
| 676 | 1.5.5 | **FUENTE DE AGUA** | 201d | 2026-06-03 | 2027-01-22 |  | 80d |  | 14,677.78 | 16 | 234 días |
| 677 | 1.5.5.1 | **FUENTE DE AGUA** | 201d | 2026-06-03 | 2027-01-22 |  | 80d |  | 14,677.78 | 16.01 | 234 días |
| 678 | 1.5.5.1.1 | **ESTRUCTURA** | 200d | 2026-06-03 | 2027-01-21 |  | 81d |  | 3,897.81 | 16.01.01 | 233 días |
| 679 | 1.5.5.1.1.1 | **TRABAJOS PRELIMINARES** | 1d | 2026-06-03 | 2026-06-04 |  | 280d |  | 25.56 | 16.01.01.01 | 2 días |
| 680 | 1.5.5.1.1.1.1 | TRAZO Y REPLANTEO PRELIMINAR | 1d | 2026-06-03 | 2026-06-04 | 682SF | 279d |  | 25.56 | 16.01.01.01.01 | 2 días |
| 681 | 1.5.5.1.1.2 | **MOVIMIENTO DE TIERRAS** | 4d | 2026-06-04 | 2026-06-08 |  | 268d |  | 780.05 | 16.01.01.02 | 5 días |
| 682 | 1.5.5.1.1.2.1 | EXCAVACION MANUAL EN TERRENO NORMAL H>1M | 1d | 2026-06-04 | 2026-06-04 | 657FF | 267d | 0d | 202.76 | 16.01.01.02.01 | 1 día |
| 683 | 1.5.5.1.1.2.2 | ACARREO MANUAL DE MATERIAL EXCEDENTE | 1d | 2026-06-05 | 2026-06-05 | 682 | 268d | 0d | 195.48 | 16.01.01.02.02 | 1 día |
| 684 | 1.5.5.1.1.2.3 | PERFILADO, NIVELACIÓN Y COMPACTADO DE ZANJA | 1d | 2026-06-06 | 2026-06-06 | 683 | 268d | 0d | 165.52 | 16.01.01.02.03 | 1 día |
| 685 | 1.5.5.1.1.2.4 | ELIMINACION MATERIAL EXCEDENTE C/MAQUINA | 1d | 2026-06-08 | 2026-06-08 | 684 | 268d | 0d | 216.29 | 16.01.01.02.04 | 1 día |
| 686 | 1.5.5.1.1.3 | **OBRAS DE CONCRETO SIMPLE** | 1d | 2027-01-16 | 2027-01-16 |  | 71d |  | 140.81 | 16.01.01.03 | 1 día |
| 687 | 1.5.5.1.1.3.1 | CONCRETO C:H 1:10 E=4" - SOLADO | 1d | 2027-01-16 | 2027-01-16 | 348FF | 71d | 0d | 140.81 | 16.01.01.03.01 | 1 día |
| 688 | 1.5.5.1.1.4 | **OBRAS DE CONCRETO ARMADO** | 4d | 2027-01-18 | 2027-01-21 |  | 71d |  | 2,951.39 | 16.01.01.04 | 4 días |
| 689 | 1.5.5.1.1.4.1 | ACERO F'Y=4200 KG/CM2 GRADO 60 | 1d | 2027-01-19 | 2027-01-19 | 690 | 71d | 0d | 649.7 | 16.01.01.04.01 | 1 día |
| 690 | 1.5.5.1.1.4.2 | ENCOFRADO Y DESENCOFRADO | 1d | 2027-01-18 | 2027-01-18 | 687 | 71d | 0d | 903.98 | 16.01.01.04.02 | 1 día |
| 691 | 1.5.5.1.1.4.3 | CONCRETO F'C=210 KG/CM2,FUENTE DE AGUA | 1d | 2027-01-20 | 2027-01-20 | 689 | 71d | 0d | 1,378.99 | 16.01.01.04.03 | 1 día |
| 692 | 1.5.5.1.1.4.4 | CURADO DE CONCRETO | 1d | 2027-01-21 | 2027-01-21 | 691 | 81d |  | 18.72 | 16.01.01.04.04 | 1 día |
| 693 | 1.5.5.1.2 | **ARQUITECTURA** | 2d | 2027-01-21 | 2027-01-22 |  | 80d |  | 1,208.27 | 16.01.02 | 2 días |
| 694 | 1.5.5.1.2.1 | **PISOS Y PAVIMENTOS** | 2d | 2027-01-21 | 2027-01-22 |  | 80d |  | 765.42 | 16.01.02.01 | 2 días |
| 695 | 1.5.5.1.2.1.1 | PISO DE PORCELANATO 60x60 cm. | 2d | 2027-01-21 | 2027-01-22 | 691 | 80d | 0d | 765.42 | 16.01.02.01.01 | 2 días |
| 696 | 1.5.5.1.2.2 | **REVOQUES Y REVESTIMIENTOS** | 1d | 2027-01-22 | 2027-01-22 |  | 80d |  | 442.85 | 16.01.02.02 | 1 día |
| 697 | 1.5.5.1.2.2.1 | ZOCALO PORCELANATO0.60x0.60 M DE (INTERIOR, JUNTA 3mm) CT | 1d | 2027-01-22 | 2027-01-22 | 695FF | 80d |  | 442.85 | 16.01.02.02.01 | 1 día |

| ID | WBS | Task | Duration | Start | Finish | Predecessors | Total slack | Free slack | Cost | Text1 | Text2 |
| --- | --- | --- | --- | --- | --- | --- | --- | --- | --- | --- | --- |
| 698 | 1.5.5.1.3 | **INSTALACION SANITARIA** | 2d | 2027-01-19 | 2027-01-20 |  | 82d |  | 9,571.7 | 16.01.03 | 2 días |
| 699 | 1.5.5.1.3.1 | **SISTEMA RECIRCULANTE** | 2d | 2027-01-19 | 2027-01-20 |  | 82d |  | 9,571.7 | 16.01.03.01 | 2 días |
| 700 | 1.5.5.1.3.1.1 | INSTALACION Y SUMINISTRO DE TUBERIA DE PVC C-5 Ø 2" | 2d | 2027-01-19 | 2027-01-20 | 689SS | 82d |  | 5,971.7 | 16.01.03.01.01 | 2 días |
| 701 | 1.5.5.1.3.1.2 | INSTALACION DEL SISTEMA DE RECIRCULACION | 1d | 2027-01-19 | 2027-01-19 | 689SS | 83d |  | 3,600 | 16.01.03.01.02 | 1 día |
| 702 | 1.5.6 | **MOBILIARIO URBANO** | 206d | 2026-06-08 | 2027-02-02 |  | 71d |  | 61,484.3 | 17 | 240 días |
| 703 | 1.5.6.1 | **PERBOLAS DE METAL CON ACABADOS DE MADERA** | 206d | 2026-06-08 | 2027-02-02 |  | 71d |  | 41,484.3 | 17.01 | 240 días |
| 704 | 1.5.6.1.1 | **ESTRUCTURA** | 199d | 2026-06-08 | 2027-01-25 |  | 78d |  | 5,356.7 | 17.01.01 | 232 días |
| 705 | 1.5.6.1.1.1 | **TRABAJOS PRELIMINARES** | 1d | 2026-06-08 | 2026-06-09 |  | 276d |  | 6.57 | 17.01.01.01 | 2 días |
| 706 | 1.5.6.1.1.1.1 | TRAZO Y REPLANTEO PRELIMINAR | 1d | 2026-06-08 | 2026-06-09 | 708SF | 275d |  | 6.57 | 17.01.01.01.01 | 2 días |
| 707 | 1.5.6.1.1.2 | **MOVIMIENTO DE TIERRAS** | 3d | 2026-06-09 | 2026-06-11 |  | 268d |  | 394.5 | 17.01.01.02 | 3 días |
| 708 | 1.5.6.1.1.2.1 | EXCAVACION MANUAL EN TERRENO NORMAL H>1M | 1d | 2026-06-09 | 2026-06-09 | 685 | 268d | 0d | 130.35 | 17.01.01.02.01 | 1 día |
| 709 | 1.5.6.1.1.2.2 | ACARREO MANUAL DE MATERIAL EXCEDENTE | 1d | 2026-06-10 | 2026-06-10 | 708 | 273d | 0d | 125.4 | 17.01.01.02.02 | 1 día |
| 710 | 1.5.6.1.1.2.3 | ELIMINACION MATERIAL EXCEDENTE C/MAQUINA | 1d | 2026-06-11 | 2026-06-11 | 709 | 273d |  | 138.75 | 17.01.01.02.03 | 1 día |
| 711 | 1.5.6.1.1.3 | **OBRAS DE CONCRETO SIMPLE** | 4d | 2027-01-21 | 2027-01-25 |  | 71d |  | 4,955.63 | 17.01.01.03 | 5 días |
| 712 | 1.5.6.1.1.3.1 | CONCRETO f'c=140 kg/cm2 + 25% PM | 1d | 2027-01-25 | 2027-01-25 | 713 | 71d | 0d | 1,132.91 | 17.01.01.03.01 | 1 día |
| 713 | 1.5.6.1.1.3.2 | ANCLAJES DE SOPORTE DE BASE DE PERBOLA | 3d | 2027-01-21 | 2027-01-23 | 691 | 71d | 0d | 3,822.72 | 17.01.01.03.02 | 3 días |
| 714 | 1.5.6.1.2 | **ARQUITECTURA** | 7d | 2027-01-26 | 2027-02-02 |  | 71d |  | 36,127.6 | 17.01.02 | 8 días |
| 715 | 1.5.6.1.2.1 | **CARPINTERIA DE MADERA** | 2d | 2027-01-26 | 2027-01-27 |  | 76d |  | 11,018 | 17.01.02.01 | 2 días |
| 716 | 1.5.6.1.2.1.1 | SUMINISTRO FABRICACION Y COLOCACION DE LISTONES DE MADERA | 2d | 2027-01-26 | 2027-01-27 | 712 | 76d |  | 11,018 | 17.01.02.01.01 | 2 días |
| 717 | 1.5.6.1.2.2 | **CARPINTERIA METALICA** | 7d | 2027-01-26 | 2027-02-02 |  | 71d |  | 25,109.6 | 17.01.02.02 | 8 días |
| 718 | 1.5.6.1.2.2.1 | SUMINISTRO FABRICACION E INSTALACION DE VIGA DE PERBOLAS | 7d | 2027-01-26 | 2027-02-02 | 712 | 71d |  | 16,164 | 17.01.02.02.01 | 8 días |
| 719 | 1.5.6.1.2.2.2 | SUMINISTRO FABRICACION Y COLOCACION DE COLUMNAS METALICAS PARA PERBOLAS | 5d | 2027-01-26 | 2027-01-30 | 712 | 73d |  | 8,945.6 | 17.01.02.02.02 | 5 días |
| 720 | 1.5.6.2 | **BANCAS DE CONCRETO CON ACERO DE 2"** | 1d | 2027-01-26 | 2027-01-26 |  | 77d |  | 20,000 | 17.02 | 1 día |
| 721 | 1.5.6.2.1 | **ESTRUCTURA** | 1d | 2027-01-26 | 2027-01-26 |  | 77d |  | 20,000 | 17.02.01 | 1 día |
| 722 | 1.5.6.2.1.1 | **CARPINTERIA METALICA** | 1d | 2027-01-26 | 2027-01-26 |  | 77d |  | 20,000 | 17.02.01.01 | 1 día |
| 723 | 1.5.6.2.1.1.1 | SUMINISTRO E INSTALACION DE BANCAS | 1d | 2027-01-26 | 2027-01-26 | 712 | 77d |  | 20,000 | 17.02.01.01.01 | 1 día |

| ID | WBS | Task | Duration | Start | Finish | Predecessors | Total slack | Free slack | Cost | Text1 | Text2 |
| --- | --- | --- | --- | --- | --- | --- | --- | --- | --- | --- | --- |
| 724 | 1.5.7 | **AREAS VERDES Y SISTEMA DE RIEGO** | 200d | 2026-06-03 | 2027-01-21 |  | 81d |  | 19,174.79 | 18 | 233 días |
| 725 | 1.5.7.1 | **AREAS VERDES Y SISTEMA DE RIEGO** | 200d | 2026-06-03 | 2027-01-21 |  | 81d |  | 19,174.79 | 18.01 | 233 días |
| 726 | 1.5.7.1.1 | **ESTRUCTURA** | 200d | 2026-06-03 | 2027-01-21 |  | 81d |  | 19,174.79 | 18.01.01 | 233 días |
| 727 | 1.5.7.1.1.1 | **AREAS VERDES** | 13d | 2026-06-03 | 2026-06-17 |  | 268d |  | 17,479.15 | 18.01.01.01 | 15 días |
| 728 | 1.5.7.1.1.1.1 | **TRABAJOS PRELIMINARES** | 1d | 2026-06-03 | 2026-06-04 |  | 280d |  | 660.01 | 18.01.01.01.01 | 2 días |
| 729 | 1.5.7.1.1.1.1.1 | TRAZO Y REPLANTEO PRELIMINAR | 1d | 2026-06-03 | 2026-06-04 | 731SF | 279d |  | 660.01 | 18.01.01.01.01.01 | 2 días |
| 730 | 1.5.7.1.1.1.2 | **MOVIMIENTO DE TIERRAS** | 12d | 2026-06-04 | 2026-06-17 |  | 268d |  | 16,819.14 | 18.01.01.01.02 | 14 días |
| 731 | 1.5.7.1.1.1.2.1 | EXCAVACION MANUAL | 5d | 2026-06-04 | 2026-06-09 | 708FF | 267d | 0d | 4,076.97 | 18.01.01.01.02.01 | 6 días |
| 732 | 1.5.7.1.1.1.2.2 | NIVELACION INTERIOR Y APISONADO | 3d | 2026-06-10 | 2026-06-12 | 731 | 268d | 0d | 1,522.66 | 18.01.01.01.02.02 | 3 días |
| 733 | 1.5.7.1.1.1.2.3 | SEMBRADO DE CESPED EN AREA VERDE | 3d | 2026-06-13 | 2026-06-16 | 732 | 268d | 0d | 9,738.11 | 18.01.01.01.02.03 | 4 días |
| 734 | 1.5.7.1.1.1.2.4 | SEMBRADO DE PLANTONES | 1d | 2026-06-17 | 2026-06-17 | 733 | 268d |  | 1,481.4 | 18.01.01.01.02.04 | 1 día |
| 735 | 1.5.7.1.1.2 | **SISTEMA DE RIEGO** | 196d | 2026-06-08 | 2027-01-21 |  | 81d |  | 1,695.64 | 18.01.01.02 | 228 días |
| 736 | 1.5.7.1.1.2.1 | **TRABAJOS PRELIMINARES** | 1d | 2026-06-08 | 2026-06-09 |  | 276d |  | 121.89 | 18.01.01.02.01 | 2 días |
| 737 | 1.5.7.1.1.2.1.1 | TRAZO Y REPLANTEO PRELIMINAR | 1d | 2026-06-08 | 2026-06-09 | 739SF | 275d |  | 121.89 | 18.01.01.02.01.01 | 2 días |
| 738 | 1.5.7.1.1.2.2 | **MOVIMIENTO DE TIERRAS** | 195d | 2026-06-09 | 2027-01-21 |  | 81d |  | 1,573.75 | 18.01.01.02.02 | 227 días |
| 739 | 1.5.7.1.1.2.2.1 | EXCAVACION MANUAL | 1d | 2026-06-09 | 2026-06-09 | 708FF | 270d | 0d | 752.79 | 18.01.01.02.02.01 | 1 día |
| 740 | 1.5.7.1.1.2.2.2 | TUBERIA PVC-SAL 4"(INCLUJE ACCESORIOS) | 1d | 2027-01-21 | 2027-01-21 | 691 | 81d |  | 820.96 | 18.01.01.02.02.02 | 1 día |
| 741 | 1.5.8 | **INSTALACIONES ELECTRICAS** | 196d | 2026-06-08 | 2027-01-21 |  | 81d |  | 20,235.62 | 19 | 228 días |
| 742 | 1.5.8.1 | **ESTRUCTURA** | 196d | 2026-06-08 | 2027-01-21 |  | 81d |  | 4,791.38 | 19.01 | 228 días |
| 743 | 1.5.8.1.1 | **TRABAJOS PRELIMINARES** | 1d | 2026-06-08 | 2026-06-09 |  | 276d |  | 13.68 | 19.01.01 | 2 días |
| 744 | 1.5.8.1.1.1 | TRAZO Y REPLANTEO PRELIMINAR | 1d | 2026-06-08 | 2026-06-09 | 746SF | 275d |  | 13.68 | 19.01.01.01 | 2 días |
| 745 | 1.5.8.1.2 | **MOVIMIENTO DE TIERRAS** | 5d | 2026-06-09 | 2026-06-13 |  | 271d |  | 1,085.9 | 19.01.02 | 5 días |
| 746 | 1.5.8.1.2.1 | EXCAVACION MANUAL EN TERRENO NORMAL H>1M | 1d | 2026-06-09 | 2026-06-09 | 739FF | 270d | 0d | 325.87 | 19.01.02.01 | 1 día |
| 747 | 1.5.8.1.2.2 | ELIMINACION MATERIAL EXCEDENTE C/MAQUINA | 1d | 2026-06-13 | 2026-06-13 | 749 | 271d |  | 347.26 | 19.01.02.02 | 1 día |
| 748 | 1.5.8.1.2.3 | ACARREO MANUAL DE MATERIAL EXCEDENTE | 2d | 2026-06-10 | 2026-06-11 | 746 | 271d | 0d | 313.84 | 19.01.02.03 | 2 días |
| 749 | 1.5.8.1.2.4 | NIVELACION Y COMPACTACION DE TERRENO | 1d | 2026-06-12 | 2026-06-12 | 748 | 271d | 0d | 98.93 | 19.01.02.04 | 1 día |

| ID | WBS | Task | Duration | Start | Finish | Predecessors | Total slack | Free slack | Cost | Text1 | Text2 |
| --- | --- | --- | --- | --- | --- | --- | --- | --- | --- | --- | --- |
| 750 | 1.5.8.1.3 | **OBRAS DE CONCRETO SIMPLE** | 1d | 2027-01-21 | 2027-01-21 |  | 81d |  | 3,691.8 | 19.01.03 | 1 día |
| 751 | 1.5.8.1.3.1 | CONCRETO F'C=210 KG/CM2 | 1d | 2027-01-21 | 2027-01-21 | 691 | 81d | 0d | 3,691.8 | 19.01.03.01 | 1 día |
| 752 | 1.5.8.2 | **INSTALACIONES ELECTRICAS** | 1d | 2027-01-21 | 2027-01-21 |  | 81d |  | 15,444.24 | 19.02 | 1 día |
| 753 | 1.5.8.2.1 | **POSTES Y TABLERO DE CONTROL** | 1d | 2027-01-21 | 2027-01-21 |  | 81d |  | 15,444.24 | 19.02.01 | 1 día |
| 754 | 1.5.8.2.1.1 | SUMINISTRO E INSTALACION POSTE METALICO FAROLA. INCL. LUMINARIA | 1d | 2027-01-21 | 2027-01-21 | 751SS | 81d |  | 15,444.24 | 19.02.01.01 | 1 día |
| 755 | 1.6 | **OBRAS EXTERIORES** | 259d | 2026-06-04 | 2027-04-01 |  | 21d |  | 574,926.75 |  | 302 días |
| 756 | 1.6.1 | **CAMINERAS** | 259d | 2026-06-04 | 2027-04-01 |  | 21d |  | 358,479.09 | 20 | 302 días |
| 757 | 1.6.1.1 | **CIRCULACION Y JUEGOS INFANTILES** | 259d | 2026-06-04 | 2027-04-01 |  | 21d |  | 358,479.09 | 20.01 | 302 días |
| 758 | 1.6.1.1.1 | **MOVIMIENTO DE TIERRAS** | 58d | 2026-06-04 | 2026-08-10 |  | 222d |  | 181,168.35 | 20.01.01 | 68 días |
| 759 | 1.6.1.1.1.1 | EXCAVACION MANUAL EN TERRENO NORMAL | 45d | 2026-06-04 | 2026-07-25 | 301 | 221d | 0d | 69,927.49 | 20.01.01.01 | 52 días |
| 760 | 1.6.1.1.1.2 | ACARREO DE MATERIAL EXCEDENTE PROVENIENTE DE EXCAVACION MANUAL | 45d | 2026-06-04 | 2026-07-25 | 759FF | 234d |  | 47,492.95 | 20.01.01.02 | 52 días |
| 761 | 1.6.1.1.1.3 | RELLENO COMPACTADO CON MATERIAL PROPIO C/PLANCHA | 30d | 2026-06-22 | 2026-07-25 | 759FF | 221d | 0d | 3,841.74 | 20.01.01.03 | 34 días |
| 762 | 1.6.1.1.1.4 | CONFORMACION DE BASE GRANULAR E=15 CM. | 2d | 2026-07-27 | 2026-07-28 | 761 | 232d |  | 12,851.29 | 20.01.01.04 | 2 días |
| 763 | 1.6.1.1.1.5 | ELIMINACION DE MATERIAL EXCEDENTE C/E D<=10km | 13d | 2026-07-27 | 2026-08-10 | 761 | 221d |  | 47,054.88 | 20.01.01.05 | 15 días |
| 764 | 1.6.1.1.2 | **OBRAS DE CONCRETO SIMPLE** | 18d | 2027-02-27 | 2027-03-19 |  | 21d |  | 90,658.68 | 20.01.02 | 21 días |
| 765 | 1.6.1.1.2.1 | ENCOFRADO Y DESENCOFRADO DE PISOS DE CONCRETO | 15d | 2027-02-27 | 2027-03-16 | 366 | 21d | 0d | 32,218.94 | 20.01.02.01 | 18 días |
| 766 | 1.6.1.1.2.2 | CONCRETO F'C=210 KG/CM2 | 6d | 2027-03-10 | 2027-03-16 | 765FF | 21d | 0d | 57,238.28 | 20.01.02.02 | 7 días |
| 767 | 1.6.1.1.2.3 | CURADO DE VERADAS DE CONCRETO | 3d | 2027-03-17 | 2027-03-19 | 765 | 32d |  | 1,201.46 | 20.01.02.03 | 3 días |
| 768 | 1.6.1.1.3 | **OBRAS DE ADOQUINES DE CONCRETO** | 17d | 2027-02-27 | 2027-03-18 |  | 33d |  | 22,686.45 | 20.01.03 | 20 días |
| 769 | 1.6.1.1.3.1 | ACARREO DE ADOQUINES DE CONCRETO | 7d | 2027-02-27 | 2027-03-06 | 765SS | 33d | 0d | 1,139.45 | 20.01.03.01 | 8 días |
| 770 | 1.6.1.1.3.2 | CAMA DE ARENA PARA PISO DE ADOQUIN | 4d | 2027-03-08 | 2027-03-11 | 769 | 33d | 0d | 3,042.33 | 20.01.03.02 | 4 días |
| 771 | 1.6.1.1.3.3 | PISO DE ADOQUINES DE CONCRETO 20x10x6 CM | 5d | 2027-03-12 | 2027-03-17 | 770 | 33d | 0d | 17,841.51 | 20.01.03.03 | 6 días |
| 772 | 1.6.1.1.3.4 | SELLO O PARCHADO DE JUNTAS CON ARENA FINA | 1d | 2027-03-18 | 2027-03-18 | 771 | 33d |  | 663.16 | 20.01.03.04 | 1 día |
| 773 | 1.6.1.1.4 | **ACABADOS** | 14d | 2027-03-17 | 2027-04-01 |  | 21d |  | 63,965.61 | 20.01.04 | 16 días |
| 774 | 1.6.1.1.4.1 | PISOS DE PIEDRA LAJA PLAZA PRINCIPAL | 14d | 2027-03-17 | 2027-04-01 | 766 | 21d |  | 63,965.61 | 20.01.04.01 | 16 días |

| ID | WBS | Task | Duration | Start | Finish | Predecessors | Total slack | Free slack | Cost | Text1 | Text2 |
| --- | --- | --- | --- | --- | --- | --- | --- | --- | --- | --- | --- |
| 775 | 1.6.2 | **RAMPAS** | 242d | 2026-06-22 | 2027-03-30 |  | 23d |  | 170,615.43 | 21 | 282 días |
| 776 | 1.6.2.1 | **MOVIMIENTO DE TIERRAS** | 33d | 2026-06-22 | 2026-07-29 |  | 232d |  | 67,170.34 | 21.01 | 38 días |
| 777 | 1.6.2.1.1 | EXCAVACION MANUAL EN TERRENO NORMAL H>1M | 30d | 2026-06-22 | 2026-07-25 | 759FF | 231d | 0d | 20,669.34 | 21.01.01 | 34 días |
| 778 | 1.6.2.1.2 | ACARREO MANUAL DE MATERIAL EXCEDENTE | 30d | 2026-06-22 | 2026-07-25 | 777FF | 234d |  | 19,906.09 | 21.01.02 | 34 días |
| 779 | 1.6.2.1.3 | RELLENO COMPACTADO CON MATERIAL PROPIO | 7d | 2026-07-18 | 2026-07-25 | 777FF | 231d | 0d | 205.67 | 21.01.03 | 8 días |
| 780 | 1.6.2.1.4 | BASE GRANULAR COMPACTADA E=0.20 M | 3d | 2026-07-27 | 2026-07-29 | 779 | 231d |  | 4,682.03 | 21.01.04 | 3 días |
| 781 | 1.6.2.1.5 | ELIMINACION MATERIAL EXCEDENTE C/MAQUINA | 2d | 2026-07-27 | 2026-07-28 | 779 | 232d |  | 21,707.21 | 21.01.05 | 2 días |
| 782 | 1.6.2.2 | **OBRAS DE CONCRETO** | 27d | 2027-02-27 | 2027-03-30 |  | 23d |  | 52,047.84 | 21.02 | 32 días |
| 783 | 1.6.2.2.1 | CONCRETO EN VEREDAS f'c=175kg/cm² ACABADO PULIDO Y BRUÑADO, E=10cm | 8d | 2027-03-22 | 2027-03-30 | 785 | 23d | 0d | 13,420.22 | 21.02.01 | 9 días |
| 784 | 1.6.2.2.2 | ACERO CORRUGADO fy=4200 kg/cm2 | 19d | 2027-02-27 | 2027-03-20 | 366 | 23d | 0d | 31,337.09 | 21.02.02 | 22 días |
| 785 | 1.6.2.2.3 | ENCOFRADO Y DESENCOFRADO | 7d | 2027-03-13 | 2027-03-20 | 784FF | 23d | 0d | 1,879.45 | 21.02.03 | 8 días |
| 786 | 1.6.2.2.4 | CURADO DE CONCRETO | 1d | 2027-03-30 | 2027-03-30 | 783FF | 23d |  | 554.39 | 21.02.04 | 1 día |
| 787 | 1.6.2.2.5 | JUNTAS DE DILATACION E=1" | 3d | 2027-03-27 | 2027-03-30 | 783FF | 23d |  | 4,856.69 | 21.02.05 | 4 días |
| 788 | 1.6.2.3 | **CARPINTERIA METALICA Y HERRERIA** | 26d | 2027-03-01 | 2027-03-30 |  | 23d |  | 51,397.25 | 21.03 | 30 días |
| 789 | 1.6.2.3.1 | BARANDA METALICA DE 2" (H=1.00m) | 26d | 2027-03-01 | 2027-03-30 | 783FF | 23d |  | 51,397.25 | 21.03.01 | 30 días |
| 790 | 1.6.3 | **GRADAS** | 191d | 2026-07-25 | 2027-03-04 |  | 45d |  | 19,058.78 | 22 | 223 días |
| 791 | 1.6.3.1 | **MOVIMIENTO DE TIERRAS** | 6d | 2026-07-25 | 2026-07-31 |  | 230d |  | 1,230.12 | 22.01 | 7 días |
| 792 | 1.6.3.1.1 | EXCAVACION MANUAL EN TERRENO NORMAL H>1M | 1d | 2026-07-25 | 2026-07-25 | 759FF | 229d | 0d | 486.55 | 22.01.01 | 1 día |
| 793 | 1.6.3.1.2 | ACARREO MANUAL DE MATERIAL EXCEDENTE | 3d | 2026-07-27 | 2026-07-29 | 792 | 229d | 0d | 468.75 | 22.01.02 | 3 días |
| 794 | 1.6.3.1.3 | COMPACTADO DE SUBRASANTE C/EQUIPO | 1d | 2026-07-30 | 2026-07-30 | 793 | 229d | 0d | 240.54 | 22.01.03 | 1 día |
| 795 | 1.6.3.1.4 | RELLENO COMPACTADO CON MATERIAL PROPIO | 1d | 2026-07-31 | 2026-07-31 | 794 | 229d |  | 34.28 | 22.01.04 | 1 día |
| 796 | 1.6.3.2 | **CONCRETO SIMPLE** | 4d | 2027-02-27 | 2027-03-03 |  | 45d |  | 14,991.85 | 22.02 | 5 días |
| 797 | 1.6.3.2.1 | CONCRETO F'C= 210 KG/CM2 | 2d | 2027-03-02 | 2027-03-03 | 798 | 45d | 0d | 13,113.81 | 22.02.01 | 2 días |
| 798 | 1.6.3.2.2 | ENCOFRADO Y DESENCOFRADO | 2d | 2027-02-27 | 2027-03-01 | 366 | 45d | 0d | 1,878.04 | 22.02.02 | 3 días |

| ID | WBS | Task | Type | Duration | Start | Finish | Predecessors | Total slack | Free slack | Cost | Text1 | Text2 |
| --- | --- | --- | --- | --- | --- | --- | --- | --- | --- | --- | --- | --- |
| 799 | 1.6.3.3 | **ACABADOS** |  | 1d | 2027-03-04 | 2027-03-04 |  | 45d |  | 2,836.81 | 22.03 | 1 día |
| 800 | 1.6.3.3.1 | PISOS DE PIEDRA LAJA PLAZA PRINCIPAL |  | 1d | 2027-03-04 | 2027-03-04 | 797 | 45d |  | 2,836.81 | 22.03.01 | 1 día |
| 801 | 1.6.4 | **JARDINERAS** |  | 200d | 2026-07-18 | 2027-03-08 |  | 42d |  | 26,773.45 | 23 | 234 días |
| 802 | 1.6.4.1 | **ESTRUCTURA** |  | 199d | 2026-07-18 | 2027-03-06 |  | 43d |  | 20,488.96 | 23.01 | 232 días |
| 803 | 1.6.4.1.1 | **TRABAJOS PRELIMINARES** |  | 1d | 2026-07-23 | 2026-07-24 |  | 237d |  | 149.07 | 23.01.01 | 2 días |
| 804 | 1.6.4.1.1.1 | TRAZO Y REPLANTEO PRELIMINAR |  | 1d | 2026-07-23 | 2026-07-24 | 806SF | 236d |  | 149.07 | 23.01.01.01 | 2 días |
| 805 | 1.6.4.1.2 | **MOVIMIENTO DE TIERRAS** |  | 8d | 2026-07-18 | 2026-07-27 |  | 234d |  | 4,943.87 | 23.01.02 | 10 días |
| 806 | 1.6.4.1.2.1 | EXCAVACION MANUAL EN TERRENO NORMAL H>1M |  | 2d | 2026-07-24 | 2026-07-25 | 759FF | 233d | 0d | 1,479.55 | 23.01.02.01 | 2 días |
| 807 | 1.6.4.1.2.2 | ACARREO MANUAL DE MATERIAL EXCEDENTE |  | 7d | 2026-07-18 | 2026-07-25 | 806FF | 234d |  | 1,425.03 | 23.01.02.02 | 8 días |
| 808 | 1.6.4.1.2.3 | ELIMINACION MATERIAL EXCEDENTE C/MAQUINA |  | 1d | 2026-07-27 | 2026-07-27 | 809 | 233d |  | 1,576.75 | 23.01.02.03 | 1 día |
| 809 | 1.6.4.1.2.4 | RELLENO MANUAL CON MATERIAL PROPIO |  | 2d | 2026-07-24 | 2026-07-25 | 806FF | 233d | 0d | 462.54 | 23.01.02.04 | 2 días |
| 810 | 1.6.4.1.3 | **OBRAS DE CONCRETO SIMPLE** |  | 7d | 2027-02-27 | 2027-03-06 |  | 42d |  | 15,396.02 | 23.01.03 | 8 días |
| 811 | 1.6.4.1.3.1 | ENCOFRADO Y DESENCOFRADO |  | 5d | 2027-02-27 | 2027-03-04 | 366 | 42d | 0d | 8,590.7 | 23.01.03.01 | 6 días |
| 812 | 1.6.4.1.3.2 | CONCRETO F'C=210 KG/CM2 |  | 1d | 2027-03-05 | 2027-03-05 | 811 | 42d | 0d | 6,624.73 | 23.01.03.02 | 1 día |
| 813 | 1.6.4.1.3.3 | CURADO DE CONCRETO |  | 1d | 2027-03-06 | 2027-03-06 | 812 | 43d |  | 180.59 | 23.01.03.03 | 1 día |
| 814 | 1.6.4.2 | **ARQUITECTURA** |  | 2d | 2027-03-06 | 2027-03-08 |  | 42d |  | 6,284.49 | 23.02 | 3 días |
| 815 | 1.6.4.2.1 | **REVOQUES Y REVESTIMIENTOS** |  | 2d | 2027-03-06 | 2027-03-08 |  | 42d |  | 6,284.49 | 23.02.01 | 3 días |
| 816 | 1.6.4.2.1.1 | ENCHAPE DE PIEDRA JARDINERAS |  | 2d | 2027-03-06 | 2027-03-08 | 812 | 42d |  | 6,284.49 | 23.02.01.01 | 3 días |
| 817 | 1.7 | Termino de Obra | milestone | 0d | 2027-04-25 | 2027-04-25 | 408 | 0d |  |  |  | 0 días |
